# Mobile Project Update v1

How a schedule from MS Project changed from version to version. A marks actual dates.

## Version 1 (data date 2018-06-18, saved 2019-09-30, file uh-mobile-plan-current-students-6-20-18-educause.mpp)

| ID | WBS | Task | Duration | Start | Finish | Predecessors | Complete | Total float | Constraint |
| --- | --- | --- | --- | --- | --- | --- | --- | --- | --- |
| 1 | 1 | **UH Mobile Project** | 393.8d? | 2017-02-08 | 2018-08-14 |  | 43% | 99.2d |  |
| 2 | 1.1 | **Establish Steering and Governance Structure** | 0d | 2017-04-03 A | 2017-04-03 A |  | 100% |  |  |
| 3 |  | Setup process to status these groups | 0d | 2017-04-03 A | 2017-04-03 A |  | 100% |  | finish no earlier than 2017-06-14 |
| 4 | 1.2 | **Acquire New Development platform (Modo and GH)** | 136d | 2017-06-08 A | 2017-12-14 A |  | 100% |  |  |
| 5 | 1.2.1 | **Modo** | 135d | 2017-06-09 A | 2017-12-14 A |  | 100% |  |  |
| 6 |  | Contract Package | 135d | 2017-06-09 A | 2017-12-14 A |  | 100% |  | finish no earlier than 2017-12-14 |
| 7 | 1.2.2 | **Grey Heller** | 88d | 2017-06-08 A | 2017-10-09 A |  | 100% |  |  |
| 8 |  | Sole Source for UHS | 88d | 2017-06-08 A | 2017-10-09 A |  | 100% |  | finish no earlier than 2017-10-09 |
| 9 | 1.3 | **Create Dedicated Mobile App Team** | 261d | 2017-02-08 | 2018-02-08 |  | 100% |  |  |
| 10 |  | Create Job Description | 23d | 2017-06-14 A | 2017-07-14 A |  | 100% |  | finish no earlier than 2017-07-14 |
| 11 |  | Post Job | 20d | 2017-07-12 A | 2017-08-08 A |  | 100% |  | finish no earlier than 2017-08-08 |
| 12 |  | Identify workspace | 4d | 2017-05-30 A | 2017-06-02 A |  | 100% |  | finish no earlier than 2017-06-02 |
| 13 |  | Create Team | 1d | 2017-07-24 A | 2017-07-24 A | 12 | 100% |  | finish no earlier than 2017-07-24 |
| 14 | 1.4 | **Engage Students** | 101d | 2017-10-05 A | 2018-02-22 A |  | 100% |  |  |
| 15 |  | Create Survey Questions | 3d | 2017-10-05 A | 2017-10-09 A |  | 100% |  | finish no earlier than 2017-10-09 |
| 16 |  | Create Accessuh Banner and Website Page | 2d | 2017-10-09 A | 2017-10-10 A |  | 100% |  | finish no earlier than 2017-10-10 |
| 17 |  | First focus group | 24d | 2017-10-09 A | 2017-11-09 A |  | 100% |  | finish no earlier than 2017-11-09 |
| 18 |  | Second Focus Group | 3d | 2017-12-06 A | 2017-12-08 A |  | 100% |  | finish no earlier than 2017-12-08 |
| 19 |  | Third Focus Group | 3d | 2018-02-20 A | 2018-02-22 A |  | 100% |  |  |
| 20 |  | Student Survey | 4d | 2017-12-08 A | 2017-12-13 A |  | 100% |  | finish no earlier than 2017-12-13 |
| 21 |  | Focus Group Final Report | 49d | 2017-12-14 A | 2018-02-20 A |  | 100% |  |  |
| 22 | 1.5 | **Engage Stakeholders and Colleagues** | 72d? | 2017-12-14 A | 2018-03-23 A |  | 100% |  |  |
| 23 |  | Strategy Meetings | 19d | 2017-12-14 A | 2018-01-09 A |  | 100% |  | finish no earlier than 2018-01-09 |
| 24 |  | Marketing Meeting | 1d | 2018-02-06 A | 2018-02-06 A |  | 100% |  | start no earlier than 2018-02-06 |
| 25 |  | Auxiliary Services Meeting | 1d | 2018-02-26 A | 2018-02-26 A |  | 100% |  | start no earlier than 2018-02-26 |
| 26 |  | Enrollment Services Meeting | 1d | 2018-02-06 A | 2018-02-06 A |  | 100% |  | start no earlier than 2018-02-06 |
| 27 |  | TouchNet Meeting | 1d | 2018-03-23 A | 2018-03-23 A |  | 100% |  | finish no earlier than 2018-03-23 |
| 28 |  | Housing Meeting | 10d? | 2018-03-12 A | 2018-03-23 A |  | 100% |  | finish no earlier than 2018-03-23 |
| 29 |  | EAB Guide Meeting | 10d? | 2018-03-12 A | 2018-03-23 A |  | 100% |  | finish no earlier than 2018-03-23 |
| 30 |  | Credentials / Authentication / Security [Placeholder] | 1d? | 2018-02-20 A | 2018-02-20 A |  | 100% |  |  |
| 31 |  | Production Schedule [Placeholder] | 1d? | 2018-02-20 A | 2018-02-20 A |  | 100% |  |  |
| 32 | 1.6 | **Grey Heller Implementation** | 125.8d? | 2018-02-20 A | 2018-08-14 |  | 58% | 99.2d |  |
| 33 | 1.6.1 | **Current Students** | 125.8d? | 2018-02-20 A | 2018-08-14 |  | 58% | 99.2d |  |
| 34 | 1.6.1.1 | **Phase 0 - Grades, Schedule, Add, Drop, Swap** | 107.7d? | 2018-02-20 A | 2018-07-19 |  | 63% | 117.3d |  |
| 35 |  | Install | 64d? | 2018-02-20 A | 2018-05-18 A |  | 100% |  | finish no earlier than 2018-05-18 |
| 36 |  | Class Search | 5d | 2018-06-19 | 2018-06-25 | 35 |  | 135d | start no earlier than 2018-06-18 |
| 37 |  | Academic Records: View My Grades | 5d | 2018-06-19 | 2018-06-25 |  |  | 135d | start no earlier than 2018-06-18 |
| 38 |  | Academic Records: My Class Schedule | 5d | 2018-06-19 | 2018-06-25 |  |  | 135d | start no earlier than 2018-06-18 |
| 39 |  | Academic Records: Enrollment: Add Classes | 5d | 2018-06-19 | 2018-06-25 |  |  | 135d | start no earlier than 2018-06-18 |
| 40 |  | Academic Records: Enrollment: Drop Classes | 5d | 2018-06-19 | 2018-06-25 |  |  | 135d | start no earlier than 2018-06-18 |
| 41 |  | Navigation | 5d | 2018-02-20 | 2018-02-26 |  |  |  | start no earlier than 2018-06-18 |
| 42 |  | Tiling | 5d | 2018-02-20 | 2018-02-26 |  |  |  | start no earlier than 2018-06-18 |
| 43 |  | Branding | 1d? | 2018-02-20 | 2018-02-20 |  |  |  | start no earlier than 2018-06-18 |
| 44 |  | Student Center: Shopping Cart | 5d | 2018-06-19 | 2018-06-25 |  |  | 135d | start no earlier than 2018-06-18 |
| 45 |  | Student Center: Enroll - Swap a Class | 5d | 2018-06-19 | 2018-06-25 |  |  | 135d | start no earlier than 2018-06-18 |
| 46 |  | Firewall Configuration for Modo Integration | 1d | 2018-02-20 A | 2018-02-20 A |  | 100% |  | finish no earlier than 2018-02-20 |
| 47 | 1.6.1.1.13 | **Testing** | 100.7d? | 2018-03-01 A | 2018-07-19 |  | 71% | 115.3d |  |
| 48 |  | Set up test accounts | 8d | 2018-03-01 A | 2018-03-12 A |  | 100% |  | finish no earlier than 2018-03-12 |
| 49 |  | Identify testers | 44d? | 2018-03-01 A | 2018-05-01 A |  | 100% |  | finish no earlier than 2018-05-01 |
| 50 |  | Perform Dev Test | 6d? | 2018-06-08 A | 2018-06-21 |  | 55% | 115.3d | start no earlier than 2018-06-08 |
| 51 |  | Perform UI/UX Test | 5d? | 2018-06-21 | 2018-06-28 | 50 |  | 115.3d | finish no earlier than 2018-06-22 |
| 52 |  | Perform BO Functional Test | 10d? | 2018-06-28 | 2018-07-12 | 51 |  | 115.3d | finish no earlier than 2018-07-06 |
| 53 |  | Perform Usability Test | 5d? | 2018-07-12 | 2018-07-19 | 52 |  | 115.3d | finish no earlier than 2018-07-09 |
| 54 | 1.6.1.1.14 | **Migrations** | 2d? | 2018-07-10 | 2018-07-12 |  |  | 0d |  |
| 55 |  | Move to TEST | 1d? | 2018-07-10 | 2018-07-10 | 53 |  |  |  |
| 56 |  | Move to Production | 1d? | 2018-07-11 | 2018-07-11 | 55 |  | 123d | start no earlier than 2018-05-28 |
| 57 |  | MS: Phase 0 Completed | 0d | 2018-07-12 | 2018-07-12 | 56 |  |  |  |
| 58 | 1.6.1.2 | **Phase 1 - Personal Information** | 98.05d? | 2018-03-01 A | 2018-07-17 |  | 62% | 119.95d |  |
| 59 |  | Personal Info: Emergency Contacts | 1d | 2018-06-19 | 2018-06-19 |  |  | 139d | start no earlier than 2018-06-18 |
| 60 |  | Personal Info: Personal Information Acknowledgement Pop-Up | 1d? | 2018-06-19 | 2018-06-19 |  |  | 139d | start no earlier than 2018-06-18 |
| 61 |  | Personal Info: Campus Emergency Notification | 1d? | 2018-06-19 | 2018-06-19 |  |  | 139d | start no earlier than 2018-06-18 |
| 62 |  | Personal Info: To Do List | 1d? | 2018-06-19 | 2018-06-19 |  |  | 139d | start no earlier than 2018-06-18 |
| 63 |  | Personal Info: Setup Security Questions | 1d? | 2018-06-19 | 2018-06-19 |  |  | 139d | start no earlier than 2018-06-18 |
| 64 |  | Personal Info: Contact Details | 1d? | 2018-06-19 | 2018-06-19 |  |  | 139d | start no earlier than 2018-06-18 |
| 65 |  | Personal Info: My Holds | 1d? | 2018-06-19 | 2018-06-19 |  |  | 139d | start no earlier than 2018-06-18 |
| 66 |  | Personal Info: My Personalizations (Campus Preferences) | 1d? | 2018-03-01 | 2018-03-01 |  |  |  | start no earlier than 2018-06-18 |
| 67 |  | Personal Info: Addresses | 1d? | 2018-06-19 | 2018-06-19 |  |  | 139d | start no earlier than 2018-06-18 |
| 68 |  | Personal Info: Password Reset | 1d? | 2018-06-19 | 2018-06-19 |  |  | 139d | start no earlier than 2018-06-18 |
| 69 |  | Personal Info: Privacy Settings | 1d? | 2018-06-19 | 2018-06-19 |  |  | 139d | start no earlier than 2018-06-18 |
| 70 |  | Personal Info: Personal Details | 1d? | 2018-06-19 | 2018-06-19 |  |  | 139d | start no earlier than 2018-06-18 |

| ID | WBS | Task | Duration | Start | Finish | Predecessors | Complete | Total float | Constraint |
| --- | --- | --- | --- | --- | --- | --- | --- | --- | --- |
| 71 |  | Personal Info: Ethnicity | 1d? | 2018-06-19 | 2018-06-19 |  |  | 139d | start no earlier than 2018-06-18 |
| 72 | 1.6.1.2.14 | **Testing** | 98.05d? | 2018-03-01 A | 2018-07-17 |  | 74% | 117.95d |  |
| 73 |  | Set up test accounts | 8d? | 2018-03-01 A | 2018-03-12 A |  | 100% |  | finish no earlier than 2018-03-12 |
| 74 |  | Identify testers | 44d? | 2018-03-01 A | 2018-05-01 A |  | 100% |  | finish no earlier than 2018-05-01 |
| 75 |  | Perform Dev Test | 7d? | 2018-06-08 A | 2018-06-20 |  | 85% | 117.95d | finish no earlier than 2018-06-18 |
| 76 |  | Perform UI/UX Test | 4d? | 2018-06-20 | 2018-06-26 | 75 |  | 117.95d | finish no earlier than 2018-06-22 |
| 77 |  | Perform Functional Test | 10d? | 2018-06-26 | 2018-07-10 | 76 |  | 117.95d | finish no earlier than 2018-07-06 |
| 78 |  | Perform Usability Test | 5d? | 2018-07-10 | 2018-07-17 | 77 |  | 117.95d | finish no earlier than 2018-07-09 |
| 79 | 1.6.1.2.15 | **Migrations** | 2d? | 2018-07-10 | 2018-07-12 |  |  | 0d |  |
| 80 |  | Move to TEST | 1d | 2018-07-10 | 2018-07-10 | 78 |  |  |  |
| 81 |  | Move to Production | 1d? | 2018-07-11 | 2018-07-11 | 80 |  | 123d | start no earlier than 2018-07-02 |
| 82 |  | MS: Phase 1 Completed | 0d | 2018-07-12 | 2018-07-12 | 81 |  |  |  |
| 83 | 1.6.1.3 | **Phase 2 - Financial Aid** | 118.8d? | 2018-03-01 A | 2018-08-14 |  | 54% | 99.2d |  |
| 84 |  | Financial Aid: To Do List | 1d | 2018-06-19 | 2018-06-19 |  |  | 139d | start no earlier than 2018-06-18 |
| 85 |  | Financial Aid: Accept/Decline Awards | 1d? | 2018-06-19 | 2018-06-19 |  |  | 139d | start no earlier than 2018-06-18 |
| 86 |  | Financial Aid: View Financial Aid | 1d? | 2018-06-19 | 2018-06-19 |  |  | 139d | start no earlier than 2018-06-18 |
| 87 |  | Financial Aid: Intended Enrollment Form | 1d? | 2018-06-19 | 2018-06-19 |  |  | 139d | start no earlier than 2018-06-18 |
| 88 |  | Financial Aid: Apply for UH Scholarships | 1d? | 2018-06-19 | 2018-06-19 |  |  | 139d | start no earlier than 2018-06-18 |
| 89 | 1.6.1.3.6 | **Testing** | 118.8d? | 2018-03-01 A | 2018-08-14 |  | 58% | 99.2d |  |
| 90 |  | Set up test accounts | 8d? | 2018-03-01 A | 2018-03-12 A |  | 100% |  | finish no earlier than 2018-03-12 |
| 91 |  | Identify testers | 44d? | 2018-03-01 A | 2018-05-01 A |  | 100% |  | finish no earlier than 2018-05-01 |
| 92 |  | Perform Dev Test | 7d? | 2018-06-08 A | 2018-06-21 |  | 60% | 99.2d | finish no earlier than 2018-06-18 |
| 93 |  | Perform UI/UX Test | 4d? | 2018-06-21 | 2018-06-27 | 92 |  | 99.2d | finish no earlier than 2018-06-22 |
| 94 |  | Perform Functional Test | 10d? | 2018-06-27 | 2018-07-11 | 93 |  | 99.2d | finish no earlier than 2018-07-06 |
| 95 |  | Perform Usability Test | 24d? | 2018-07-11 | 2018-08-14 | 94 |  | 99.2d | finish no earlier than 2018-06-01 |
| 96 | 1.6.1.3.7 | **Migrations** | 10d? | 2018-06-19 | 2018-07-02 |  |  | 0d |  |
| 97 |  | Move to TEST | 1d | 2018-06-19 | 2018-06-19 |  |  |  |  |
| 98 |  | Move to Production | 1d? | 2018-07-02 | 2018-07-02 |  |  | 130d | start no earlier than 2018-07-02 |
| 99 |  | MS: Phase 2 Completed | 1d? | 2018-06-19 | 2018-06-19 |  |  |  | start no earlier than 2018-06-18 |
| 100 | 1.6.1.4 | **Phase 3 - Academic Records, Enrollment** | 99.57d? | 2018-03-01 A | 2018-07-18 |  | 54% | 118.43d |  |
| 101 |  | Academic Records: Enrollment Dates | 1d | 2018-06-19 | 2018-06-19 |  |  | 139d | start no earlier than 2018-06-18 |
| 102 |  | Academic Records: View AAEC Approval Status | 1d? | 2018-06-19 | 2018-06-19 |  |  | 139d | start no earlier than 2018-06-18 |
| 103 |  | Academic Records: Forward Form to Faculty | 1d? | 2018-06-19 | 2018-06-19 |  |  | 139d | start no earlier than 2018-06-18 |
| 104 |  | Academic Records: Browse Catalog | 1d? | 2018-06-19 | 2018-06-19 |  |  | 139d | start no earlier than 2018-06-18 |
| 105 |  | Academic Records: View Unofficial Transcript | 1d? | 2018-06-19 | 2018-06-19 |  |  | 139d | start no earlier than 2018-06-18 |
| 106 |  | Academic Records: UH_Official_Transcript | 1d? | 2018-06-19 | 2018-06-19 |  |  | 139d | start no earlier than 2018-06-18 |
| 107 |  | Academic Records: Request Enrollment Verification | 1d? | 2018-06-19 | 2018-06-19 |  |  | 139d | start no earlier than 2018-06-18 |
| 108 |  | Advising: Apply for Graduation | 1d? | 2018-03-01 | 2018-03-01 |  |  |  | start no earlier than 2018-06-18 |
| 109 |  | Academic Records: Request Term Withdrawal | 1d? | 2018-06-19 | 2018-06-19 |  |  | 139d | start no earlier than 2018-06-18 |
| 110 |  | Academic Records: View Faculty Approval Status | 1d? | 2018-06-19 | 2018-06-19 |  |  | 139d | start no earlier than 2018-06-18 |
| 111 |  | Academic Records: View My Weekly Schedule | 1d? | 2018-06-19 | 2018-06-19 |  |  | 139d | start no earlier than 2018-06-18 |
| 112 |  | Academic Records: View Transfer Credit Report | 1d? | 2018-06-19 | 2018-06-19 |  |  | 139d | start no earlier than 2018-06-18 |
| 113 |  | Academic Records: Class Search | 1d? | 2018-06-19 | 2018-06-19 |  |  | 139d | start no earlier than 2018-06-18 |
| 114 |  | Student Center: Schedule Planner | 1d? | 2018-06-19 | 2018-06-19 |  |  | 139d | start no earlier than 2018-06-18 |
| 115 |  | Student Center: My Planner | 1d? | 2018-06-19 | 2018-06-19 |  |  | 139d | start no earlier than 2018-06-18 |
| 116 | 1.6.1.4.16 | **Testing** | 99.57d? | 2018-03-01 A | 2018-07-18 |  | 65% | 118.43d |  |
| 117 |  | Set up test accounts | 8d? | 2018-03-01 A | 2018-03-12 A |  | 100% |  | finish no earlier than 2018-03-12 |
| 118 |  | Identify testers | 44d? | 2018-03-01 A | 2018-05-01 A |  | 100% |  | finish no earlier than 2018-05-01 |
| 119 |  | Perform Dev Test | 1d? | 2018-06-08 A | 2018-06-19 |  | 43% | 118.43d | start no earlier than 2018-06-08 |
| 120 |  | Perform UI/UX Test | 10d? | 2018-06-19 | 2018-07-03 | 119 |  | 118.43d | start no earlier than 2018-06-18 |
| 121 |  | Perform Functional Test | 11d? | 2018-07-03 | 2018-07-18 | 120 |  | 118.43d |  |
| 122 |  | Perform Usability Test | 7d? | 2018-07-02 | 2018-07-10 |  |  | 122d | finish no earlier than 2018-07-10 |
| 123 | 1.6.1.4.17 | **Migrations** | 2d? | 2018-07-11 | 2018-07-13 |  |  | 0d |  |
| 124 |  | Move to TEST | 1d | 2018-07-11 | 2018-07-11 | 122 |  |  |  |
| 125 |  | Move to Production | 1d? | 2018-07-12 | 2018-07-12 | 124 |  | 122d | start no earlier than 2018-07-02 |
| 126 |  | MS: Phase 3 Completed | 0d | 2018-07-13 | 2018-07-13 | 125 |  |  |  |
| 127 | 1.6.1.5 | **Phase 4 - Student Financials** | 96.85d? | 2018-03-01 A | 2018-07-13 |  | 56% | 121.15d |  |
| 128 |  | Student Financials: Account Summary | 1d | 2018-06-19 | 2018-06-19 |  |  | 139d | start no earlier than 2018-06-18 |
| 129 |  | Student Financials: Pending Financial Aid | 1d? | 2018-06-19 | 2018-06-19 |  |  | 139d | start no earlier than 2018-06-18 |
| 130 |  | Student Financials: BOA-Velocity Payment Page for Credit Cards linked from above | 1d? | 2018-06-19 | 2018-06-19 |  |  | 139d | start no earlier than 2018-06-18 |
| 131 |  | Student Financials: Charges Due | 1d? | 2018-06-19 | 2018-06-19 |  |  | 139d | start no earlier than 2018-06-18 |
| 132 |  | Student Financials: Account Balance | 1d? | 2018-06-19 | 2018-06-19 |  |  | 139d | start no earlier than 2018-06-18 |
| 133 |  | Student Financials: Payment Plans | 1d? | 2018-06-19 | 2018-06-19 |  |  | 139d | start no earlier than 2018-06-18 |
| 134 |  | Student Financials: Optional Fees | 1d? | 2018-06-19 | 2018-06-19 |  |  | 139d | start no earlier than 2018-06-18 |
| 135 |  | Student Financials: Make a Payment | 1d? | 2018-06-19 | 2018-06-19 |  |  | 139d | start no earlier than 2018-06-18 |
| 136 |  | Student Financials: Self Service 1098T | 1d? | 2018-06-19 | 2018-06-19 |  |  | 139d | start no earlier than 2018-06-18 |
| 137 |  | Student Financials: Payment History | 1d? | 2018-06-19 | 2018-06-19 |  |  | 139d | start no earlier than 2018-06-18 |
| 138 |  | Student Financials: UH in 4 Fixed Rate Tuition Plan | 1d? | 2018-06-19 | 2018-06-19 |  |  | 139d | start no earlier than 2018-06-18 |
| 139 |  | Student Financials: Self Service Refund Request | 1d? | 2018-06-19 | 2018-06-19 |  |  | 139d | start no earlier than 2018-06-18 |
| 140 |  | Student Communications Center: Communications to Student (if available) | 1d? | 2018-06-19 | 2018-06-19 |  |  | 139d | start no earlier than 2018-06-18 |

| ID | WBS | Task | Duration | Start | Finish | Predecessors | Complete | Total float | Constraint |
| --- | --- | --- | --- | --- | --- | --- | --- | --- | --- |
| 141 |  | Advising: UH in 4 Graduation Plan | 1d? | 2018-03-01 | 2018-03-01 |  |  |  | start no earlier than 2018-06-18 |
| 142 |  | Advising: List of Advisors Link | 1d? | 2018-03-01 | 2018-03-01 |  |  |  | start no earlier than 2018-06-18 |
| 143 |  | Advising: View My Appointments | 1d? | 2018-03-01 | 2018-03-01 |  |  |  | start no earlier than 2018-06-18 |
| 144 |  | Advising: Appointment with Advisor | 1d? | 2018-03-01 | 2018-03-01 |  |  |  | start no earlier than 2018-06-18 |
| 145 |  | Advising: Appointment with ISSSO | 1d? | 2018-03-01 | 2018-03-01 |  |  |  | start no earlier than 2018-06-18 |
| 146 |  | Advising: Graduation Status | 1d? | 2018-03-01 | 2018-03-01 |  |  |  | start no earlier than 2018-06-18 |
| 147 |  | JumpForward: JumpForward Website | 1d? | 2018-03-01 | 2018-03-01 |  |  |  | start no earlier than 2018-06-18 |
| 148 |  | Advising: Apply for Graduation | 1d? | 2018-03-01 | 2018-03-01 |  |  |  | start no earlier than 2018-06-18 |
| 149 |  | UHS Acknowledgement Center: Student Acknowledgements (if available) | 1d? | 2018-06-19 | 2018-06-19 |  |  | 139d | start no earlier than 2018-06-18 |
| 150 | 1.6.1.5.23 | **Testing** | 96.85d? | 2018-03-01 A | 2018-07-13 |  | 75% | 119.15d |  |
| 151 |  | Set up test accounts | 8d? | 2018-03-01 A | 2018-03-12 A |  | 100% |  | finish no earlier than 2018-03-12 |
| 152 |  | Identify testers | 44d? | 2018-03-01 A | 2018-05-01 A |  | 100% |  | finish no earlier than 2018-05-01 |
| 153 |  | Perform Dev Test | 7d? | 2018-06-08 A | 2018-06-22 |  | 45% | 119.15d | finish no earlier than 2018-06-18 |
| 154 |  | Perform UI/UX Test | 4d? | 2018-06-22 | 2018-06-28 | 153 |  | 119.15d | finish no earlier than 2018-06-22 |
| 155 |  | Perform Functional Test | 10d? | 2018-06-28 | 2018-07-12 | 154 |  | 119.15d | finish no earlier than 2018-07-06 |
| 156 |  | Perform Usability Test | 1d? | 2018-07-12 | 2018-07-13 | 155 |  | 119.15d | finish no earlier than 2018-07-10 |
| 157 | 1.6.1.5.24 | **Migrations** | 2d? | 2018-07-11 | 2018-07-13 |  |  | 0d |  |
| 158 |  | Move to TEST | 1d | 2018-07-11 | 2018-07-11 | 156 |  |  |  |
| 159 |  | Move to Production | 1d? | 2018-07-12 | 2018-07-12 | 158 |  | 122d | start no earlier than 2018-07-02 |
| 160 |  | MS: Phase 4 Completed | 0d | 2018-07-13 | 2018-07-13 | 159 |  |  |  |
| 161 | 1.7 | **Modo Labs Tasks** | 119d? | 2018-02-20 A | 2018-08-03 |  | 28% | 106d |  |
| 162 | 1.7.1 | **Create Initial Test Apps** | 109d | 2018-02-20 A | 2018-07-20 |  | 14% | 0d |  |
| 163 |  | Send Modo Labs Invites to iTunes, Apple Developer, and Google Play | 1d | 2018-02-20 A | 2018-02-20 A |  | 100% |  |  |
| 164 |  | Retrieve user UDIDs for iOS test apps | 1d | 2018-02-20 A | 2018-02-20 A |  | 100% |  |  |
| 165 |  | Modo Labs will confirm access and retrieve certificates for app creation | 1d | 2018-02-20 A | 2018-02-20 A |  | 100% |  |  |
| 166 |  | Test apps will be distributed | 1d | 2018-02-20 A | 2018-02-20 A |  | 100% |  |  |
| 167 |  | Clean-up Test platform | 24d | 2018-06-19 | 2018-07-20 |  |  |  |  |
| 168 | 1.7.2 | **Blackboard Integration** | 65d | 2018-04-02 | 2018-06-29 |  | 54% |  |  |
| 169 |  | Setup Building Block in BB | 14d | 2018-05-14 A | 2018-05-31 A |  | 100% |  |  |
| 170 |  | Configure Modo | 12d | 2018-05-31 A | 2018-06-26 |  | 50% |  |  |
| 171 |  | Test | 11d | 2018-06-19 | 2018-07-03 |  |  |  |  |
| 172 | 1.7.3 | **Authentication** | 73d | 2018-02-20 A | 2018-05-31 |  | 85% |  |  |
| 173 |  | SSO | 1d | 2018-02-20 A | 2018-02-20 A |  | 100% |  |  |
| 174 |  | Shibboleth for other services | 55d | 2018-04-02 A | 2018-06-15 A |  | 100% |  |  |
| 175 |  | Create authentication page | 10d | 2018-05-28 | 2018-06-08 |  |  | 146d | finish no earlier than 2018-06-08 |
| 176 | 1.7.4 | **Communicate** | 14d | 2018-06-19 | 2018-07-06 |  |  | 0d |  |
| 177 | 1.7.4.1 | **Establish policy (Modo)** | 10d | 2018-06-19 | 2018-07-02 |  |  | 0d |  |
| 178 |  | Draft | 10d | 2018-06-19 | 2018-07-02 |  |  |  |  |
| 179 |  | Final | 5d | 2018-06-19 | 2018-06-25 |  |  |  |  |
| 180 |  | Create message channels | 14d | 2018-06-19 | 2018-07-06 |  |  |  |  |
| 181 |  | Confirm test notifications can be received on test app | 1d | 2018-06-19 | 2018-06-19 |  |  | 139d | start no earlier than 2018-06-18 |
| 182 | 1.7.5 | **Analytics** | 10d | 2018-07-09 | 2018-07-20 |  |  | 0d |  |
| 183 |  | Configure | 10d | 2018-07-09 | 2018-07-20 |  |  |  |  |
| 184 | 1.7.6 | **Marketing and Communications** | 115d | 2018-02-20 A | 2018-07-30 |  | 16% | 108d |  |
| 185 |  | Create new name (UH Go) | 29d | 2018-02-20 A | 2018-07-19 |  | 21% | -79d | finish no earlier than 2018-03-30 |
| 186 |  | Communication Plan | 30d | 2018-06-19 | 2018-07-30 |  |  |  |  |
| 187 |  | Marketing Plan | 30d | 2018-06-19 | 2018-07-30 |  |  |  |  |
| 188 | 1.7.6.4 | **UH Go IA** | 29d | 2018-05-01 | 2018-06-08 |  |  |  |  |
| 189 |  | Wireframes | 1d | 2018-05-01 | 2018-05-01 |  |  |  | start no earlier than 2018-06-18 |
| 190 |  | Documentation | 1d | 2018-05-01 | 2018-05-01 |  |  |  | start no earlier than 2018-06-18 |
| 191 |  | Create Navigation | 6d | 2018-06-19 | 2018-06-26 |  |  | 132d | start no earlier than 2018-06-18 |
| 192 | 1.7.6.5 | **Themes** | 30d | 2018-06-18 A | 2018-07-27 |  | 27% | 0d |  |
| 193 |  | App Theme (parent that everything in app inherits) | 29d | 2018-06-19 | 2018-07-27 |  |  |  |  |
| 194 |  | Modules and Screens | 29d | 2018-06-19 | 2018-07-27 |  |  |  |  |
| 195 |  | Style Guideline for Content Owners | 1d | 2018-06-18 | 2018-06-18 |  |  |  | start no earlier than 2018-06-18 |
| 196 | 1.7.6.5.4 | **App Design** | 14d | 2018-06-18 A | 2018-07-05 |  | 82% | 0d |  |
| 197 |  | Logo for UH Go! | 1d | 2018-06-29 | 2018-06-29 |  |  |  |  |
| 198 |  | Home Page: University of Houston Persona | 14d | 2018-06-18 A | 2018-07-05 |  | 85% |  |  |
| 199 |  | Student Persona | 14d | 2018-06-18 A | 2018-07-05 |  | 85% |  |  |
| 200 | 1.7.7 | **Development** | 114d? | 2018-02-20 A | 2018-07-27 |  | 30% | 111d |  |
| 201 | 1.7.7.1 | **Content & Services** | 114d? | 2018-02-20 A | 2018-07-27 |  | 30% | 111d |  |
| 202 | 1.7.7.1.1 | **myUH (GreyHeller)** | 1d | 2018-02-20 A | 2018-02-20 A |  | 100% |  |  |
| 203 |  | Authentication via Shibboleth (SSO) | 1d | 2018-02-20 A | 2018-02-20 A |  | 100% |  |  |
| 204 |  | Create IA | 1d | 2018-02-20 A | 2018-02-20 A |  | 100% |  |  |
| 205 |  | Build screens/navigation | 1d | 2018-02-20 A | 2018-02-20 A |  | 100% |  |  |
| 206 | 1.7.7.1.2 | **Housing** | 40d? | 2018-06-04 A | 2018-07-27 |  | 42% | 111d |  |
| 207 |  | Housing Stakeholder Meeting | 20d? | 2018-06-04 A | 2018-06-29 A |  | 100% |  | start no earlier than 2018-06-04 |
| 208 | 1.7.7.1.2.2 | **Move-in Guide** | 1d | 2018-06-19 | 2018-06-19 |  |  | 0d |  |
| 209 |  | create screen so that we can add Fix-it button that logs into AccessUH to request room maintenance | 1d | 2018-06-19 | 2018-06-19 |  |  |  |  |
| 210 |  | Xcomponent proof of concept using residential data | 1d | 2018-06-19 | 2018-06-19 |  |  |  |  |

| ID | WBS | Task | Duration | Start | Finish | Predecessors | Complete | Total float | Constraint |
| --- | --- | --- | --- | --- | --- | --- | --- | --- | --- |
| 211 | 1.7.7.1.2.3 | **Become a Resident** | 16.6d | 2018-06-04 A | 2018-06-26 |  | 90% | 134.4d |  |
| 212 |  | Apply for Housing | 2d | 2018-06-06 A | 2018-06-19 |  | 90% | 139.8d | start no earlier than 2018-06-06 |
| 213 |  | LaundryView Integration | 7d | 2018-06-04 A | 2018-06-26 |  | 90% | 132.4d | start no earlier than 2018-06-04 |
| 214 |  | Marketing evaluation | 2d | 2018-06-26 | 2018-06-28 | 213 |  | 132.4d | start no earlier than 2018-06-18 |
| 215 |  | Module configuration | 5d | 2018-06-19 A | 2018-06-29 A | 214 | 100% |  | finish no earlier than 2018-06-29 |
| 216 | 1.7.7.1.2.6 | **Testing** | 20d? | 2018-07-02 | 2018-07-27 |  |  | 111d |  |
| 217 |  | Dev Testing | 5d | 2018-07-02 | 2018-07-06 | 215 |  | 111d | start no earlier than 2018-06-25 |
| 218 |  | BO Testing | 10d | 2018-07-09 | 2018-07-20 | 217 |  | 111d | start no earlier than 2018-06-25 |
| 219 | 1.7.7.1.2.6.3 | **Functional Testing** | 5d? | 2018-07-23 | 2018-07-27 |  |  | 111d |  |
| 220 |  | iOS | 5d? | 2018-07-23 | 2018-07-27 | 218 |  | 111d | finish no earlier than 2018-07-27 |
| 221 |  | Android | 5d? | 2018-07-23 | 2018-07-27 | 218 |  | 111d | finish no earlier than 2018-07-27 |
| 222 |  | Usability Testing | 5d | 2018-07-23 | 2018-07-27 | 218 |  | 111d | finish no earlier than 2018-07-27 |
| 223 |  | Bug Fixing | 5d? | 2018-07-23 | 2018-07-27 | 218 |  | 111d | finish no earlier than 2018-07-27 |
| 224 |  | Marketing sign-off | 5d | 2018-07-23 | 2018-07-27 |  |  | 111d | finish no earlier than 2018-07-27 |
| 225 | 1.7.7.1.3 | **Parking** | 85d? | 2018-04-02 A | 2018-07-27 |  | 16% | 111d |  |
| 226 |  | Parking Stakeholder Meeting | 20d | 2018-04-02 A | 2018-06-08 A |  | 100% |  | finish no earlier than 2018-06-29 |
| 227 |  | B-Cycle parking bike share [Before Fall] | 2d | 2018-06-28 | 2018-06-29 |  |  | 131d | finish no earlier than 2018-06-29 |
| 228 |  | Park Mobile | 2d | 2018-06-28 | 2018-06-29 |  |  | 131d | finish no earlier than 2018-06-29 |
| 229 |  | Pre-purchase parking | 2d | 2018-06-28 | 2018-06-29 |  |  | 131d | finish no earlier than 2018-06-29 |
| 230 |  | T2 | 2d | 2018-06-28 | 2018-06-29 |  |  | 131d | finish no earlier than 2018-06-29 |
| 231 |  | Parking citations | 2d | 2018-06-28 | 2018-06-29 |  |  | 131d | finish no earlier than 2018-06-29 |
| 232 |  | Rent a car | 2d | 2018-06-28 | 2018-06-29 |  |  | 131d | finish no earlier than 2018-06-29 |
| 233 |  | Order Tow | 2d | 2018-06-28 | 2018-06-29 |  |  | 131d | finish no earlier than 2018-06-29 |
| 234 | 1.7.7.1.3.9 | **Testing** | 35d? | 2018-06-11 | 2018-07-27 |  |  | 111d |  |
| 235 |  | Dev Testing | 15d? | 2018-06-11 | 2018-06-29 |  |  | 131d | finish no earlier than 2018-06-29 |
| 236 |  | UI/UX testing (infomal user testing) | 15d | 2018-06-18 | 2018-07-06 |  |  | 126d | finish no earlier than 2018-07-06 |
| 237 |  | BO Testing | 15d? | 2018-06-25 | 2018-07-13 |  |  | 121d | finish no earlier than 2018-07-13 |
| 238 | 1.7.7.1.3.9.4 | **Functional Testing** | 10d? | 2018-06-25 | 2018-07-06 |  |  | 126d |  |
| 239 |  | iOS | 10d? | 2018-06-25 | 2018-07-06 |  |  | 126d | finish no earlier than 2018-07-06 |
| 240 |  | Android | 10d? | 2018-06-25 | 2018-07-06 |  |  | 126d | finish no earlier than 2018-07-06 |
| 241 |  | Usability Testing | 10d? | 2018-07-02 | 2018-07-13 |  |  | 121d | finish no earlier than 2018-07-13 |
| 242 |  | Bug Fixing | 10d? | 2018-07-09 | 2018-07-20 |  |  | 116d | finish no earlier than 2018-07-20 |
| 243 |  | Marketing sign-off | 10d | 2018-07-16 | 2018-07-27 |  |  | 111d | finish no earlier than 2018-07-27 |
| 244 | 1.7.7.1.4 | **Dining** | 114d? | 2018-02-20 A | 2018-07-27 |  | 1% | 111d |  |
| 245 |  | Dining Stakeholder Meeting | 2d | 2018-02-20 A | 2018-06-19 |  | 50% | 139d |  |
| 246 |  | Boost App [ordering] | 2d | 2018-06-19 | 2018-06-20 |  |  | 138d | start no earlier than 2018-06-18 |
| 247 |  | Pickup | 2d | 2018-06-19 | 2018-06-20 |  |  | 138d | start no earlier than 2018-06-18 |
| 248 |  | Pre-payment | 2d | 2018-06-19 | 2018-06-20 |  |  | 138d | start no earlier than 2018-06-18 |
| 249 |  | Express pickup (Integrated with meal plans and CougarCash) | 2d | 2018-06-19 | 2018-06-20 |  |  | 138d | start no earlier than 2018-06-18 |
| 250 | 1.7.7.1.4.6 | **Dine on Campus** | 20d? | 2018-06-04 | 2018-06-29 |  |  | 131d |  |
| 251 |  | Menus | 20d? | 2018-06-04 | 2018-06-29 |  |  | 131d | finish no earlier than 2018-06-29 |
| 252 |  | Hours of Operation | 20d? | 2018-06-04 | 2018-06-29 |  |  | 131d | finish no earlier than 2018-06-29 |
| 253 |  | Food Trucks - RSS feed | 1d | 2018-06-29 | 2018-06-29 |  |  | 131d | finish no earlier than 2018-06-29 |
| 254 | 1.7.7.1.4.7 | **My Fitness Pal** | 2d | 2018-06-28 | 2018-06-29 |  |  | 131d |  |
| 255 |  | Calories, allergen info, etc. | 2d | 2018-06-28 | 2018-06-29 |  |  | 131d | finish no earlier than 2018-06-29 |
| 256 | 1.7.7.1.4.8 | **Testing** | 35d? | 2018-06-11 | 2018-07-27 |  |  | 111d |  |
| 257 |  | Dev Testing | 15d? | 2018-06-11 | 2018-06-29 |  |  | 131d | finish no earlier than 2018-06-29 |
| 258 |  | UI/UX Testing | 15d? | 2018-06-19 | 2018-07-09 |  |  | 125d | start no earlier than 2018-06-18 |
| 259 |  | BO Testing | 15d? | 2018-06-19 | 2018-07-09 |  |  | 125d | start no earlier than 2018-06-18 |
| 260 | 1.7.7.1.4.8.4 | **Functional Testing** | 10d? | 2018-06-25 | 2018-07-06 |  |  | 126d |  |
| 261 |  | iOS | 10d? | 2018-06-25 | 2018-07-06 |  |  | 126d | finish no earlier than 2018-07-06 |
| 262 |  | Android | 10d? | 2018-06-25 | 2018-07-06 |  |  | 126d | finish no earlier than 2018-07-06 |
| 263 |  | Usability Testing | 10d? | 2018-07-02 | 2018-07-13 |  |  | 121d | finish no earlier than 2018-07-13 |
| 264 |  | Bug Fixing | 10d? | 2018-07-09 | 2018-07-20 |  |  | 116d | finish no earlier than 2018-07-20 |
| 265 |  | Marketing sign-off | 10d? | 2018-07-16 | 2018-07-27 |  |  | 111d | finish no earlier than 2018-07-27 |
| 266 | 1.7.7.1.5 | **Library** | 40d | 2018-06-04 A | 2018-07-27 |  | 60% | 111d |  |
| 267 |  | Library Stakeholder Meeting | 1d | 2018-06-04 A | 2018-06-04 A |  | 100% |  | start no earlier than 2018-06-18 |
| 268 |  | Hours | 3d | 2018-06-11 A | 2018-06-13 A | 267 | 100% |  | finish no earlier than 2018-06-13 |
| 269 |  | News | 0.25d | 2018-06-18 A | 2018-06-18 | 268 | 75% |  |  |
| 270 |  | Calendar | 3d | 2018-06-11 A | 2018-06-13 A | 269 | 100% |  |  |
| 271 |  | Check-out System | 5d | 2018-06-11 A | 2018-06-15 A | 270 | 100% |  |  |
| 272 | 1.7.7.1.5.6 | **Testing** | 16d | 2018-06-29 | 2018-07-20 |  |  | 116d |  |
| 273 |  | Dev Testing | 1d | 2018-06-29 | 2018-06-29 | 271 |  | 128d | finish no earlier than 2018-06-29 |
| 274 |  | UI/UX Testing | 1d | 2018-07-06 | 2018-07-06 | 273 |  | 124d | finish no earlier than 2018-07-06 |
| 275 |  | BO Testin | 1d | 2018-07-13 | 2018-07-13 | 274 |  | 120d | finish no earlier than 2018-07-13 |
| 276 | 1.7.7.1.5.6.4 | **Functional Testing** | 1d | 2018-07-16 | 2018-07-16 |  |  | 120d |  |
| 277 |  | iOS | 1d | 2018-07-16 | 2018-07-16 | 275 |  | 120d | finish no earlier than 2018-07-06 |
| 278 |  | Android | 1d | 2018-07-16 | 2018-07-16 | 275 |  | 120d | finish no earlier than 2018-07-06 |
| 279 |  | Usability Testing | 1d | 2018-07-16 | 2018-07-16 | 275 |  | 120d | finish no earlier than 2018-07-13 |
| 280 |  | Bug Fixing | 1d | 2018-07-20 | 2018-07-20 | 275 |  | 116d | finish no earlier than 2018-07-20 |

| ID | WBS | Task | Duration | Start | Finish | Predecessors | Complete | Total float | Constraint |
| --- | --- | --- | --- | --- | --- | --- | --- | --- | --- |
| 281 |  | Marketing sign-off | 1d | 2018-07-27 | 2018-07-27 | 275 |  | 111d | finish no earlier than 2018-07-27 |
| 282 | 1.7.7.1.6 | **Social** | 15.2d | 2018-06-04 A | 2018-06-25 |  | 16% | 135.8d |  |
| 283 |  | Facebook | 5d | 2018-06-04 A | 2018-06-25 |  | 16% | 135.8d | finish no earlier than 2018-06-08 |
| 284 |  | Twitter | 5d | 2018-06-04 A | 2018-06-25 |  | 16% | 135.8d | finish no earlier than 2018-06-08 |
| 285 |  | YouTube | 5d | 2018-06-04 A | 2018-06-25 |  | 16% | 135.8d | finish no earlier than 2018-06-08 |
| 286 |  | Testing | 5d | 2018-06-04 A | 2018-06-25 |  | 16% | 135.8d | finish no earlier than 2018-06-08 |
| 287 | 1.7.7.1.7 | **UIT Guide** | 40d? | 2018-06-04 A | 2018-07-27 |  | 11% | 111d |  |
| 288 |  | UIT Stakeholder Meeting | 5d | 2018-06-04 A | 2018-06-20 |  | 75% | 138.75d | finish no earlier than 2018-06-08 |
| 289 |  | Chat Functionality | 5d? | 2018-06-04 A | 2018-06-20 |  | 75% | 138.75d | finish no earlier than 2018-06-08 |
| 290 |  | Interactive FAQ | 5d? | 2018-06-04 A | 2018-06-20 |  | 75% | 138.75d | finish no earlier than 2018-06-08 |
| 291 |  | pull out items within service dashboard | 1d | 2018-06-06 A | 2018-06-19 |  | 75% | 139.75d | start no earlier than 2018-06-06 |
| 292 | 1.7.7.1.7.5 | **Testing** | 30d? | 2018-06-11 | 2018-07-20 |  |  | 116d |  |
| 293 |  | Dev Testing | 15d? | 2018-06-11 | 2018-06-29 |  |  | 131d | finish no earlier than 2018-06-29 |
| 294 |  | UI/UX Testing | 15d? | 2018-06-18 | 2018-07-06 |  |  | 126d | finish no earlier than 2018-07-06 |
| 295 |  | BO Testin | 15d? | 2018-06-25 | 2018-07-13 |  |  | 121d | finish no earlier than 2018-07-13 |
| 296 | 1.7.7.1.7.5.4 | **Functional Testing** | 10d? | 2018-06-25 | 2018-07-06 |  |  | 126d |  |
| 297 |  | iOS | 10d? | 2018-06-25 | 2018-07-06 |  |  | 126d | finish no earlier than 2018-07-06 |
| 298 |  | Android | 10d? | 2018-06-25 | 2018-07-06 |  |  | 126d | finish no earlier than 2018-07-06 |
| 299 |  | Usability Testing | 10d? | 2018-07-02 | 2018-07-13 |  |  | 121d | finish no earlier than 2018-07-13 |
| 300 |  | Bug Fixing | 10d? | 2018-07-09 | 2018-07-20 |  |  | 116d | finish no earlier than 2018-07-20 |
| 301 |  | Marketing sign-off | 10d? | 2018-07-16 | 2018-07-27 |  |  | 111d | finish no earlier than 2018-07-27 |
| 302 | 1.7.7.1.8 | **News** | 80d? | 2018-04-02 A | 2018-07-20 |  | 32% | 116d |  |
| 303 |  | Daily Cougar | 1d | 2018-04-02 A | 2018-04-02 A |  | 100% |  | finish no earlier than 2018-04-19 |
| 304 |  | RSS feeds | 14d | 2018-04-02 A | 2018-04-19 A |  | 100% |  | finish no earlier than 2018-04-19 |
| 305 |  | Pull in images | 5d | 2018-06-04 A | 2018-06-08 A |  | 100% |  | finish no earlier than 2018-06-08 |
| 306 | 1.7.7.1.8.4 | **Testing** | 30d? | 2018-06-11 A | 2018-07-20 |  | 6% | 116d |  |
| 307 |  | Dev Testing | 0d | 2018-06-11 A | 2018-06-11 A |  | 100% |  |  |
| 308 |  | UI/UX Testing | 5d? | 2018-06-18 | 2018-06-22 |  |  | 136d | finish no earlier than 2018-06-22 |
| 309 |  | BO Testing | 5d? | 2018-06-25 | 2018-06-29 |  |  | 131d | finish no earlier than 2018-06-29 |
| 310 | 1.7.7.1.8.4.4 | **Functional Testing** | 10d | 2018-06-25 A | 2018-07-06 |  | 8% | 126d |  |
| 311 |  | iOS | 10d | 2018-06-25 A | 2018-07-06 |  | 8% | 126d | finish no earlier than 2018-07-06 |
| 312 |  | Android | 10d | 2018-06-25 A | 2018-07-06 |  | 8% | 126d | finish no earlier than 2018-07-06 |
| 313 |  | Usability Testing | 10d | 2018-07-02 A | 2018-07-13 |  | 8% | 121d | finish no earlier than 2018-07-13 |
| 314 |  | Bug Fixing | 10d | 2018-07-09 A | 2018-07-20 |  | 8% | 116d | finish no earlier than 2018-07-20 |
| 315 |  | Marketing sign-off | 5d | 2018-07-16 A | 2018-07-20 |  | 16% | 116d | finish no earlier than 2018-07-20 |
| 316 | 1.7.7.1.9 | **Calendar** | 80d? | 2018-04-02 A | 2018-07-20 |  | 84% | 116d |  |
| 317 |  | Build X componant blocks | 2d | 2018-06-06 A | 2018-06-07 A |  | 100% |  | finish no earlier than 2018-04-19 |
| 318 |  | iCAL Format | 14d | 2018-04-02 A | 2018-04-19 A |  | 100% |  | finish no earlier than 2018-04-19 |
| 319 | 1.7.7.1.9.3 | **Testing** | 30d? | 2018-06-11 A | 2018-07-20 |  | 88% | 116d |  |
| 320 |  | Dev Testing | 0d | 2018-06-11 A | 2018-06-11 A |  | 100% |  |  |
| 321 |  | UI/UX Testing | 5d? | 2018-06-18 A | 2018-06-22 A |  | 100% |  | finish no earlier than 2018-06-22 |
| 322 |  | BO Testing | 5d? | 2018-06-25 A | 2018-06-29 A |  | 100% |  | finish no earlier than 2018-06-29 |
| 323 | 1.7.7.1.9.3.4 | **Functional Testing** | 10d | 2018-06-25 A | 2018-07-06 A |  | 100% |  |  |
| 324 |  | iOS | 10d | 2018-06-25 A | 2018-07-06 A |  | 100% |  | finish no earlier than 2018-07-06 |
| 325 |  | Android | 10d | 2018-06-25 A | 2018-07-06 A |  | 100% |  | finish no earlier than 2018-07-06 |
| 326 |  | Usability Testing | 10d | 2018-07-02 A | 2018-07-13 |  | 94% | 121d | finish no earlier than 2018-07-13 |
| 327 |  | Bug Fixing | 10d | 2018-07-09 A | 2018-07-20 |  | 44% | 116d | finish no earlier than 2018-07-20 |
| 328 |  | Marketing sign-off | 5d | 2018-07-16 | 2018-07-20 |  |  | 116d | finish no earlier than 2018-07-20 |
| 329 | 1.7.7.1.10 | **Directory** | 54d? | 2018-04-02 A | 2018-06-14 A |  | 100% |  |  |
| 330 |  | CSV/JSON API feed | 14d | 2018-04-02 A | 2018-04-19 A |  | 100% |  | finish no earlier than 2018-04-19 |
| 331 | 1.7.7.1.10.2 | **Testing** | 9d? | 2018-06-04 A | 2018-06-14 A |  | 100% |  |  |
| 332 |  | Dev Testing | 5d | 2018-06-04 A | 2018-06-08 A |  | 100% |  | finish no earlier than 2018-06-08 |
| 333 |  | UI/UX Testing | 4d? | 2018-06-11 A | 2018-06-14 A |  | 100% |  | finish no earlier than 2018-06-14 |
| 334 |  | BO Testing | 4d? | 2018-06-11 A | 2018-06-14 A |  | 100% |  | finish no earlier than 2018-06-14 |
| 335 | 1.7.7.1.10.2.4 | **Functional Testing** | 4d | 2018-06-11 A | 2018-06-14 A |  | 100% |  |  |
| 336 |  | iOS | 4d | 2018-06-11 A | 2018-06-14 A |  | 100% |  | finish no earlier than 2018-06-14 |
| 337 |  | Android | 4d | 2018-06-11 A | 2018-06-14 A |  | 100% |  | finish no earlier than 2018-06-14 |
| 338 |  | Usability Testing | 4d | 2018-06-11 A | 2018-06-14 A |  | 100% |  | finish no earlier than 2018-06-14 |
| 339 |  | Bug Fixing | 4d | 2018-06-11 A | 2018-06-14 A |  | 100% |  | finish no earlier than 2018-06-14 |
| 340 |  | Marketing sign-off | 4d | 2018-06-11 A | 2018-06-14 A |  | 100% |  | finish no earlier than 2018-06-14 |
| 341 | 1.7.7.1.11 | **Shuttle Routes** | 70d? | 2018-04-02 A | 2018-07-06 |  | 50% | 126d |  |
| 342 |  | Shuttle Routes | 14d | 2018-04-02 A | 2018-04-19 A |  | 100% |  | finish no earlier than 2018-04-19 |
| 343 |  | DoubleMap Integration | 14d | 2018-04-02 A | 2018-04-19 A |  | 100% |  | finish no earlier than 2018-04-19 |
| 344 | 1.7.7.1.11.3 | **Testing** | 20d? | 2018-06-04 A | 2018-06-29 |  | 14% | 131d |  |
| 345 |  | Dev Testing | 5d | 2018-06-04 A | 2018-06-22 |  | 20% | 136d | finish no earlier than 2018-06-08 |
| 346 |  | UI/UX Testing | 5d? | 2018-06-11 | 2018-06-15 |  |  | 141d | finish no earlier than 2018-06-15 |
| 347 |  | BO Testing | 5d? | 2018-06-18 | 2018-06-22 |  |  | 136d | finish no earlier than 2018-06-22 |
| 348 | 1.7.7.1.11.3.4 | **Functional Testing** | 10d | 2018-06-11 A | 2018-06-22 |  | 20% | 136d |  |
| 349 |  | iOS | 5d | 2018-06-11 A | 2018-06-22 |  | 20% | 136d | finish no earlier than 2018-06-15 |
| 350 |  | Android | 5d | 2018-06-11 A | 2018-06-22 |  | 20% | 136d | finish no earlier than 2018-06-15 |

| ID | WBS | Task | Duration | Start | Finish | Predecessors | Complete | Total float | Constraint |
| --- | --- | --- | --- | --- | --- | --- | --- | --- | --- |
| 351 |  | Usability Testing | 5d | 2018-06-18 A | 2018-06-22 |  | 20% | 136d | finish no earlier than 2018-06-22 |
| 352 |  | Bug Fixing | 5d | 2018-06-25 A | 2018-06-29 |  | 20% | 131d | finish no earlier than 2018-06-29 |
| 353 |  | Marketing sign-off | 5d | 2018-07-02 A | 2018-07-06 |  | 20% | 126d | finish no earlier than 2018-07-06 |
| 354 | 1.7.7.1.12 | **Student Media** | 70d? | 2018-04-02 A | 2018-07-06 |  | 59% | 126d |  |
| 355 |  | The Cougar | 14d | 2018-04-02 A | 2018-04-19 A |  | 100% |  | finish no earlier than 2018-04-19 |
| 356 |  | CougarTV | 14d | 2018-04-02 A | 2018-04-19 A |  | 100% |  | finish no earlier than 2018-04-19 |
| 357 |  | Coog Radio | 14d | 2018-04-02 A | 2018-04-19 A |  | 100% |  | finish no earlier than 2018-04-19 |
| 358 | 1.7.7.1.12.4 | **Testing** | 20d? | 2018-06-04 A | 2018-06-29 |  | 14% | 131d |  |
| 359 |  | Dev Testing | 5d | 2018-06-04 A | 2018-06-22 |  | 20% | 136d | finish no earlier than 2018-06-08 |
| 360 |  | UI/UX Testing | 5d? | 2018-06-11 | 2018-06-15 |  |  | 141d | finish no earlier than 2018-06-15 |
| 361 |  | BO Testing | 5d? | 2018-06-18 | 2018-06-22 |  |  | 136d | finish no earlier than 2018-06-22 |
| 362 | 1.7.7.1.12.4.4 | **Functional Testing** | 10d | 2018-06-11 A | 2018-06-22 |  | 20% | 136d |  |
| 363 |  | iOS | 5d | 2018-06-11 A | 2018-06-22 |  | 20% | 136d | finish no earlier than 2018-06-15 |
| 364 |  | Android | 5d | 2018-06-11 A | 2018-06-22 |  | 20% | 136d | finish no earlier than 2018-06-15 |
| 365 |  | Usability Testing | 5d | 2018-06-18 A | 2018-06-22 |  | 20% | 136d | finish no earlier than 2018-06-22 |
| 366 |  | Bug Fixing | 5d | 2018-06-25 A | 2018-06-29 |  | 20% | 131d | finish no earlier than 2018-06-29 |
| 367 |  | Marketing sign-off | 5d | 2018-07-02 A | 2018-07-06 |  | 20% | 126d | finish no earlier than 2018-07-06 |
| 368 | 1.7.7.1.13 | **Maps** | 15d | 2018-06-04 A | 2018-06-22 |  | 77% | 136d |  |
| 369 |  | Way-finder | 8d | 2018-06-04 A | 2018-06-13 A |  | 100% |  | finish no earlier than 2018-04-19 |
| 370 | 1.7.7.1.13.2 | **Testing** | 10d | 2018-06-11 A | 2018-06-22 |  | 68% | 136d |  |
| 371 |  | Dev Testing | 1d | 2018-06-11 A | 2018-06-11 A |  | 100% |  | finish no earlier than 2018-06-29 |
| 372 |  | UI/UX Testing | 5d | 2018-06-11 A | 2018-06-15 A |  | 100% |  | finish no earlier than 2018-07-06 |
| 373 |  | BO Testing | 5d | 2018-06-11 A | 2018-06-15 A |  | 100% |  | finish no earlier than 2018-06-15 |
| 374 | 1.7.7.1.13.2.4 | **Functional Testing** | 5d | 2018-06-18 A | 2018-06-22 |  | 50% | 136d |  |
| 375 |  | iOS | 5d | 2018-06-18 A | 2018-06-22 |  | 50% | 136d | finish no earlier than 2018-06-22 |
| 376 |  | Android | 5d | 2018-06-18 A | 2018-06-22 |  | 50% | 136d | finish no earlier than 2018-06-22 |
| 377 |  | Usability Testing | 5d | 2018-06-18 A | 2018-06-22 |  | 50% | 136d | finish no earlier than 2018-06-22 |
| 378 |  | Bug Fixing | 5d | 2018-06-18 A | 2018-06-22 |  | 50% | 136d | finish no earlier than 2018-06-22 |
| 379 |  | Marketing sign-off | 5d | 2018-06-18 A | 2018-06-22 A |  | 100% |  | finish no earlier than 2018-06-22 |
| 380 | 1.7.7.1.14 | **Alerts** | 28.1d | 2018-06-14 A | 2018-07-24 |  | 29% | 114.9d |  |
| 381 | 1.7.7.1.14.1 | **Emergency Notifications** | 2d | 2018-07-09 | 2018-07-10 |  |  | 0d |  |
| 382 |  | how does Marketing want it to work? | 2d | 2018-07-09 | 2018-07-10 | 213, 271 |  |  |  |
| 383 |  | Configure API | 1d | 2018-06-14 A | 2018-06-14 |  | 97% | 8.9d | start no earlier than 2018-06-14 |
| 384 | 1.7.7.1.14.3 | **Testing** | 26d | 2018-06-15 A | 2018-07-20 |  | 26% | 0d |  |
| 385 |  | Dev Testing | 2d | 2018-06-15 | 2018-06-18 | 383 |  | 8.9d | finish no earlier than 2018-06-15 |
| 386 |  | UI/UX Testing | 2d | 2018-06-21 | 2018-06-22 | 385 |  | 6.9d | finish no earlier than 2018-06-22 |
| 387 |  | BO Testing | 2d | 2018-06-28 | 2018-06-29 | 386 |  | 3.9d | finish no earlier than 2018-06-29 |
| 388 | 1.7.7.1.14.3.4 | **Functional Testing** | 11.1d | 2018-06-25 A | 2018-07-10 |  | 45% | 2.8d |  |
| 389 |  | iOS | 2d | 2018-06-25 A | 2018-07-06 | 387 | 45% | 0d | finish no earlier than 2018-07-06 |
| 390 |  | Android | 2d | 2018-06-25 A | 2018-07-10 | 389 | 45% | 2.8d | finish no earlier than 2018-07-06 |
| 391 |  | Usability Testing | 2d | 2018-07-02 A | 2018-07-13 | 390 | 45% | 3.9d | finish no earlier than 2018-07-13 |
| 392 |  | Bug Fixing | 2d | 2018-07-09 A | 2018-07-20 | 391 | 45% | 0d | finish no earlier than 2018-07-20 |
| 393 |  | Marketing sign-off | 2d | 2018-07-16 A | 2018-07-24 | 392 | 45% | 114.9d | finish no earlier than 2018-07-20 |
| 394 | 1.7.7.1.15 | **UH Tours** | 30d? | 2018-06-18 A | 2018-07-27 |  | 11% | 111d |  |
| 395 |  | migrate art assets to map | 14d | 2018-06-19 | 2018-07-06 |  |  | 126d | start no earlier than 2018-06-18 |
| 396 | 1.7.7.1.15.2 | **Testing** | 25d? | 2018-06-18 A | 2018-07-20 |  | 14% | 116d |  |
| 397 |  | Dev Testing | 5d | 2018-06-18 A | 2018-06-22 |  | 20% | 136d | finish no earlier than 2018-06-22 |
| 398 |  | UI/UX Testing | 5d? | 2018-06-25 | 2018-06-29 |  |  | 131d | start no earlier than 2018-06-25 |
| 399 |  | BO Testing | 5d? | 2018-07-02 | 2018-07-06 |  |  | 126d | start no earlier than 2018-07-02 |
| 400 | 1.7.7.1.15.2.4 | **Functional Testing** | 5d | 2018-07-02 A | 2018-07-06 |  | 20% | 126d |  |
| 401 |  | iOS | 5d | 2018-07-02 A | 2018-07-06 |  | 20% | 126d | finish no earlier than 2018-07-06 |
| 402 |  | Android | 5d | 2018-07-02 A | 2018-07-06 |  | 20% | 126d | finish no earlier than 2018-07-06 |
| 403 |  | Usability Testing | 5d | 2018-07-09 A | 2018-07-13 |  | 20% | 121d | finish no earlier than 2018-07-13 |
| 404 |  | Bug Fixing | 5d | 2018-07-16 A | 2018-07-20 |  | 20% | 116d | finish no earlier than 2018-07-20 |
| 405 |  | Marketing sign-off | 5d | 2018-07-23 A | 2018-07-27 |  | 20% | 111d | finish no earlier than 2018-07-27 |
| 406 | 1.7.7.1.16 | **Sugar Land** | 10d? | 2018-06-04 A | 2018-06-15 A |  | 100% |  |  |
| 407 |  | Add Geo-location | 5d | 2018-06-04 A | 2018-06-08 A |  | 100% |  |  |
| 408 |  | Wayfinding | 4d? | 2018-06-08 A | 2018-06-13 A |  | 100% |  | finish no earlier than 2018-06-13 |
| 409 | 1.7.7.1.16.3 | **Testing** | 2d? | 2018-06-14 A | 2018-06-15 A |  | 100% |  |  |
| 410 |  | Dev Testing | 2d? | 2018-06-14 A | 2018-06-15 A |  | 100% |  | start no earlier than 2018-06-14 |
| 411 |  | UI/UX Testing | 2d? | 2018-06-14 A | 2018-06-15 A |  | 100% |  | finish no earlier than 2018-06-15 |
| 412 |  | BO Testing | 2d? | 2018-06-14 A | 2018-06-15 A |  | 100% |  | finish no earlier than 2018-06-15 |
| 413 | 1.7.7.1.16.3.4 | **Functional Testing** | 2d? | 2018-06-14 A | 2018-06-15 A |  | 100% |  |  |
| 414 |  | iOS | 2d? | 2018-06-14 A | 2018-06-15 A |  | 100% |  | finish no earlier than 2018-06-15 |
| 415 |  | Android | 2d? | 2018-06-14 A | 2018-06-15 A |  | 100% |  | finish no earlier than 2018-06-15 |
| 416 |  | Usability Testing | 2d? | 2018-06-14 A | 2018-06-15 A |  | 100% |  | finish no earlier than 2018-06-15 |
| 417 |  | Bug Fixing | 2d? | 2018-06-14 A | 2018-06-15 A |  | 100% |  | finish no earlier than 2018-06-15 |
| 418 |  | Marketing sign-off | 2d? | 2018-06-14 A | 2018-06-15 A |  | 100% |  | finish no earlier than 2018-06-15 |
| 419 | 1.7.7.1.17 | **Weeks of Welcome** | 40d? | 2018-06-04 A | 2018-07-27 |  | 4% | 111d |  |
| 420 |  | Content | 20d | 2018-06-04 A | 2018-07-12 |  | 10% | 122d | finish no earlier than 2018-06-29 |

| ID | WBS | Task | Duration | Start | Finish | Complete | Total float | Constraint |
| --- | --- | --- | --- | --- | --- | --- | --- | --- |
| 421 |  | Pilot iBeacons using Aruba | 30d | 2018-06-13 A | 2018-07-25 | 10% | 113d | start no earlier than 2018-06-13 |
| 422 |  | QR codes | 20d | 2018-06-04 A | 2018-07-12 | 10% | 122d | finish no earlier than 2018-06-29 |
| 423 | 1.7.7.1.17.4 | **Testing** | 24d? | 2018-06-19 | 2018-07-20 |  | 116d |  |
| 424 |  | Dev Testing | 15d? | 2018-06-19 | 2018-07-09 |  | 125d | start no earlier than 2018-06-18 |
| 425 |  | UI/UX Testing | 15d? | 2018-06-19 | 2018-07-09 |  | 125d | start no earlier than 2018-06-18 |
| 426 |  | BO Testing | 15d? | 2018-06-25 | 2018-07-13 |  | 121d | start no earlier than 2018-06-25 |
| 427 | 1.7.7.1.17.4.4 | **Functional Testing** | 10d? | 2018-06-25 | 2018-07-06 |  | 126d |  |
| 428 |  | iOS | 10d? | 2018-06-25 | 2018-07-06 |  | 126d | start no earlier than 2018-06-25 |
| 429 |  | Android | 10d? | 2018-06-25 | 2018-07-06 |  | 126d | start no earlier than 2018-06-25 |
| 430 |  | Usability Testing | 10d? | 2018-07-02 | 2018-07-13 |  | 121d | start no earlier than 2018-07-02 |
| 431 |  | Bug Fixing | 10d? | 2018-07-09 | 2018-07-20 |  | 116d | start no earlier than 2018-07-09 |
| 432 |  | Marketing sign-off | 10d? | 2018-07-16 | 2018-07-27 |  | 111d | start no earlier than 2018-07-16 |
| 433 | 1.7.7.1.18 | **OEM** | 29d? | 2018-06-19 | 2018-07-27 |  | 111d |  |
| 434 |  | Be Prepared | 5d? | 2018-06-19 | 2018-06-25 |  | 135d | start no earlier than 2018-06-18 |
| 435 | 1.7.7.1.18.2 | **Testing** | 24d? | 2018-06-19 | 2018-07-20 |  | 116d |  |
| 436 |  | Dev Testing | 15d? | 2018-06-19 | 2018-07-09 |  | 125d | start no earlier than 2018-06-18 |
| 437 |  | UI/UX Testing | 15d? | 2018-06-19 | 2018-07-09 |  | 125d | start no earlier than 2018-06-18 |
| 438 |  | BO Testing | 15d? | 2018-06-25 | 2018-07-13 |  | 121d | start no earlier than 2018-06-25 |
| 439 | 1.7.7.1.18.2.4 | **Functional Testing** | 10d? | 2018-06-25 | 2018-07-06 |  | 126d |  |
| 440 |  | iOS | 10d? | 2018-06-25 | 2018-07-06 |  | 126d | start no earlier than 2018-06-25 |
| 441 |  | Android | 10d? | 2018-06-25 | 2018-07-06 |  | 126d | start no earlier than 2018-06-25 |
| 442 |  | Usability Testing | 10d? | 2018-07-02 | 2018-07-13 |  | 121d | start no earlier than 2018-07-02 |
| 443 |  | Bug Fixing | 10d? | 2018-07-09 | 2018-07-20 |  | 116d | start no earlier than 2018-07-09 |
| 444 |  | Marketing sign-off | 10d? | 2018-07-16 | 2018-07-27 |  | 111d | start no earlier than 2018-07-16 |
| 445 |  | Provost | 21d? | 2018-06-04 A | 2018-07-03 | 50% | 129.5d |  |
| 446 | 1.7.7.1.20 | **CFI** | 8d? | 2018-06-04 A | 2018-06-13 A | 100% |  |  |
| 447 |  | update map (create CFI filter) | 5d | 2018-06-04 A | 2018-06-08 A | 100% |  |  |
| 448 |  | add content | 3d | 2018-06-11 A | 2018-06-13 A | 100% |  |  |
| 449 | 1.7.7.1.20.3 | **Testing** | 3d? | 2018-06-11 A | 2018-06-13 A | 100% |  |  |
| 450 |  | Dev Testing | 3d? | 2018-06-11 A | 2018-06-13 A | 100% |  | finish no earlier than 2018-06-13 |
| 451 |  | UI/UX Testing | 3d? | 2018-06-11 A | 2018-06-13 A | 100% |  | finish no earlier than 2018-06-13 |
| 452 |  | BO Testing | 3d? | 2018-06-11 A | 2018-06-13 A | 100% |  | finish no earlier than 2018-06-13 |
| 453 | 1.7.7.1.20.3.4 | **Functional Testing** | 3d? | 2018-06-11 A | 2018-06-13 A | 100% |  |  |
| 454 |  | iOS | 3d? | 2018-06-11 A | 2018-06-13 A | 100% |  | finish no earlier than 2018-06-13 |
| 455 |  | Android | 3d? | 2018-06-11 A | 2018-06-13 A | 100% |  | finish no earlier than 2018-06-13 |
| 456 |  | Usability Testing | 3d? | 2018-06-11 A | 2018-06-13 A | 100% |  | finish no earlier than 2018-06-13 |
| 457 |  | Bug Fixing | 3d? | 2018-06-11 A | 2018-06-13 A | 100% |  | finish no earlier than 2018-06-13 |
| 458 |  | Marketing sign-off | 3d? | 2018-06-11 A | 2018-06-13 A | 100% |  | finish no earlier than 2018-06-13 |
| 459 | 1.7.7.1.21 | **Feedback** | 40d? | 2018-06-04 | 2018-07-27 |  | 111d |  |
| 460 |  | Web hook | 20d? | 2018-06-04 | 2018-06-29 |  | 131d | finish no earlier than 2018-06-29 |
| 461 | 1.7.7.1.21.2 | **Testing** | 30d? | 2018-06-11 | 2018-07-20 |  | 116d |  |
| 462 |  | Dev Testing | 15d? | 2018-06-11 | 2018-06-29 |  | 131d | finish no earlier than 2018-06-29 |
| 463 |  | UI/UX Testing | 15d? | 2018-06-18 | 2018-07-06 |  | 126d | finish no earlier than 2018-07-06 |
| 464 |  | BO Testing | 15d? | 2018-06-25 | 2018-07-13 |  | 121d | finish no earlier than 2018-07-13 |
| 465 | 1.7.7.1.21.2.4 | **Functional Testing** | 10d? | 2018-06-25 | 2018-07-06 |  | 126d |  |
| 466 |  | iOS | 10d? | 2018-06-25 | 2018-07-06 |  | 126d | finish no earlier than 2018-07-06 |
| 467 |  | Android | 10d? | 2018-06-25 | 2018-07-06 |  | 126d | finish no earlier than 2018-07-06 |
| 468 |  | Usability Testing | 10d? | 2018-07-02 | 2018-07-13 |  | 121d | finish no earlier than 2018-07-13 |
| 469 |  | Bug Fixing | 10d? | 2018-07-09 | 2018-07-20 |  | 116d | finish no earlier than 2018-07-20 |
| 470 |  | Marketing sign-off | 10d? | 2018-07-16 | 2018-07-27 |  | 111d | finish no earlier than 2018-07-27 |
| 471 | 1.7.7.1.22 | **EAB Guide** | 100d? | 2018-03-12 A | 2018-07-27 | 34% | 111d |  |
| 472 |  | sent email requesting schema | 20d? | 2018-06-04 A | 2018-06-29 A | 100% |  | finish no earlier than 2018-06-29 |
| 473 | 1.7.7.1.22.2 | **Testing** | 30d? | 2018-06-11 | 2018-07-20 |  | 116d |  |
| 474 |  | Dev Testing | 15d? | 2018-06-11 | 2018-06-29 |  | 131d | finish no earlier than 2018-06-29 |
| 475 |  | UI/UX Testing | 15d? | 2018-06-18 | 2018-07-06 |  | 126d | finish no earlier than 2018-07-06 |
| 476 |  | BO Testing | 15d? | 2018-06-25 | 2018-07-13 |  | 121d | finish no earlier than 2018-07-13 |
| 477 | 1.7.7.1.22.2.4 | **Functional Testing** | 10d? | 2018-06-25 | 2018-07-06 |  | 126d |  |
| 478 |  | Mobile Web | 10d? | 2018-06-25 | 2018-07-06 |  | 126d | finish no earlier than 2018-07-06 |
| 479 |  | iOS | 10d? | 2018-06-25 | 2018-07-06 |  | 126d | finish no earlier than 2018-07-06 |
| 480 |  | Android | 10d? | 2018-06-25 | 2018-07-06 |  | 126d | finish no earlier than 2018-07-06 |
| 481 |  | Usability Testing | 10d? | 2018-07-02 | 2018-07-13 |  | 121d | finish no earlier than 2018-07-13 |
| 482 |  | Bug Fixing | 10d? | 2018-07-09 | 2018-07-20 |  | 116d | finish no earlier than 2018-07-20 |
| 483 |  | Marketing sign-off | 30d? | 2018-06-18 A | 2018-07-27 | 50% | 111d | start no earlier than 2018-06-18 |
| 484 | 1.7.7.1.22.4 | **Authentication/Security** | 68d? | 2018-03-12 A | 2018-06-13 | 99% | 0d |  |
| 485 |  | Determine authentication type (done) | 10d | 2018-03-12 A | 2018-03-23 A | 100% |  | finish no earlier than 2018-03-23 |
| 486 |  | Set up Shibboleth | 1d? | 2018-06-13 A | 2018-06-13 A | 100% |  | start no earlier than 2018-06-18 |
| 487 |  | Apply to either modules or persona | 10d | 2018-03-12 A | 2018-03-23 A | 100% |  | finish no earlier than 2018-03-23 |
| 488 |  | Authentication/Security Testing | 1d? | 2018-06-13 A | 2018-06-13 A | 100% |  | start no earlier than 2018-06-13 |
| 489 | 1.7.8 | **Personas** | 40d? | 2018-06-04 A | 2018-07-27 | 5% | 111d |  |
| 490 |  | University of Houston | 5d | 2018-06-04 A | 2018-06-22 | 30% | 136d | finish no earlier than 2018-06-22 |

| ID | WBS | Task | Duration | Start | Finish | Predecessors | Complete | Total float | Constraint |
| --- | --- | --- | --- | --- | --- | --- | --- | --- | --- |
| 491 |  | Student | 5d | 2018-06-04 A | 2018-06-22 |  | 30% | 136d | finish no earlier than 2018-06-22 |
| 492 | 1.7.8.3 | **Testing** | 25d? | 2018-06-18 | 2018-07-20 |  |  | 116d |  |
| 493 |  | Dev Testing | 5d? | 2018-06-18 | 2018-06-22 |  |  | 136d | finish no earlier than 2018-06-22 |
| 494 |  | UI/UX Testing | 5d? | 2018-06-25 | 2018-06-29 |  |  | 131d | finish no earlier than 2018-06-29 |
| 495 |  | BO Testing | 5d? | 2018-07-02 | 2018-07-06 |  |  | 126d | finish no earlier than 2018-07-06 |
| 496 | 1.7.8.3.4 | **Functional Testing** | 5d? | 2018-06-25 | 2018-06-29 |  |  | 131d |  |
| 497 |  | iOS | 5d? | 2018-06-25 | 2018-06-29 |  |  | 131d | finish no earlier than 2018-06-29 |
| 498 |  | Android | 5d? | 2018-06-25 | 2018-06-29 |  |  | 131d | finish no earlier than 2018-06-29 |
| 499 |  | Usability Testing | 10d? | 2018-07-02 | 2018-07-13 |  |  | 121d | finish no earlier than 2018-07-13 |
| 500 |  | Bug Fixing | 10d? | 2018-07-09 | 2018-07-20 |  |  | 116d | finish no earlier than 2018-07-20 |
| 501 |  | Marketing sign-off | 10d? | 2018-07-16 | 2018-07-27 |  |  | 111d | finish no earlier than 2018-07-27 |
| 502 | 1.7.9 | **Locations** | 40d? | 2018-06-04 | 2018-07-27 |  |  | 111d |  |
| 503 |  | Central | 15d? | 2018-06-04 | 2018-06-22 |  |  | 136d | finish no earlier than 2018-06-22 |
| 504 |  | Sugar Land | 15d? | 2018-06-04 | 2018-06-22 |  |  | 136d | finish no earlier than 2018-06-22 |
| 505 | 1.7.9.3 | **Testing** | 25d? | 2018-06-18 | 2018-07-20 |  |  | 116d |  |
| 506 |  | Dev Testing | 5d? | 2018-06-18 | 2018-06-22 |  |  | 136d | finish no earlier than 2018-06-22 |
| 507 |  | UI/UX Testing | 5d? | 2018-06-25 | 2018-06-29 |  |  | 131d | finish no earlier than 2018-06-29 |
| 508 |  | BO Testing | 5d? | 2018-07-02 | 2018-07-06 |  |  | 126d | finish no earlier than 2018-07-06 |
| 509 | 1.7.9.3.4 | **Functional Testing** | 5d? | 2018-06-25 | 2018-06-29 |  |  | 131d |  |
| 510 |  | iOS | 5d? | 2018-06-25 | 2018-06-29 |  |  | 131d | finish no earlier than 2018-06-29 |
| 511 |  | Android | 5d? | 2018-06-25 | 2018-06-29 |  |  | 131d | finish no earlier than 2018-06-29 |
| 512 |  | Usability Testing | 10d? | 2018-07-02 | 2018-07-13 |  |  | 121d | finish no earlier than 2018-07-13 |
| 513 |  | Bug Fixing | 10d? | 2018-07-09 | 2018-07-20 |  |  | 116d | finish no earlier than 2018-07-20 |
| 514 |  | Marketing sign-off | 10d? | 2018-07-16 | 2018-07-27 |  |  | 111d | finish no earlier than 2018-07-27 |
| 515 | 1.7.10 | **Roles and Security** | 5d? | 2018-05-21 A | 2018-05-25 A |  | 100% |  |  |
| 516 |  | Create | 5d? | 2018-05-21 A | 2018-05-25 A |  | 100% |  | finish no earlier than 2018-05-25 |
| 517 |  | Communicate | 5d? | 2018-05-21 A | 2018-05-25 A |  | 100% |  | finish no earlier than 2018-05-25 |
| 518 |  | Analyze | 5d? | 2018-05-21 A | 2018-05-25 A |  | 100% |  | finish no earlier than 2018-05-25 |
| 519 | 1.7.11 | **Prepare App for Stores in Modo** | 2d? | 2018-07-30 | 2018-07-31 | 185, 191 |  | 109d |  |
| 520 |  | TestFlight | 2d? | 2018-07-30 | 2018-07-31 |  |  | 109d | finish no earlier than 2018-07-31 |
| 521 | 1.7.12 | **App Submission** | 3d | 2018-08-01 A | 2018-08-03 |  | 11% | 106d |  |
| 522 |  | Submission checklists | 3d | 2018-08-01 A | 2018-08-03 |  | 33% | 106d | finish no earlier than 2018-08-03 |
| 523 |  | Publish mobile website | 3d | 2018-08-01 A | 2018-08-03 |  | 33% | 106d | finish no earlier than 2018-08-03 |
| 524 |  | Submit iOS app to app store | 3d | 2018-08-01 | 2018-08-03 |  |  | 106d | finish no earlier than 2018-08-03 |
| 525 |  | Wait for app store approval | 3d | 2018-08-01 | 2018-08-03 |  |  | 106d | finish no earlier than 2018-08-03 |
| 526 |  | iOS app release in app store | 3d | 2018-08-01 | 2018-08-03 |  |  | 106d | finish no earlier than 2018-08-03 |
| 527 |  | Submit android app | 3d | 2018-08-01 | 2018-08-03 |  |  | 106d | finish no earlier than 2018-08-03 |
| 528 |  | MS: Go-Live (Modo Applications) | 0d | 2018-08-01 | 2018-08-01 |  |  |  |  |
| 529 |  | MS: Go-Live (Grey Heller) | 0d | 2018-08-01 | 2018-08-01 |  |  |  |  |
| 530 | 1.7.13 | **Business Owner Training** | 15d? | 2018-06-19 | 2018-07-09 |  |  | 125d |  |
| 531 |  | Marketing Training | 5d | 2018-07-03 | 2018-07-09 | 532 |  | 125d |  |
| 532 |  | Auxiliary Services Training | 10d? | 2018-06-19 | 2018-07-02 |  |  | 125d | start no earlier than 2018-06-18 |
| 533 |  | Housing Training | 10d? | 2018-06-19 | 2018-07-02 |  |  | 130d | start no earlier than 2018-06-18 |
| 534 |  | Enrollment Services Training | 10d? | 2018-06-19 | 2018-07-02 |  |  | 130d | start no earlier than 2018-06-18 |
| 535 | 1.7.14 | **Establish Institutional Policies** | 10d? | 2018-05-21 | 2018-06-01 |  |  | 151d |  |
| 536 | 1.7.14.1 | **App Policies** | 10d? | 2018-05-21 | 2018-06-01 |  |  | 151d |  |
| 537 |  | Permissions Policy | 5d? | 2018-05-21 | 2018-05-25 |  |  | 156d | finish no earlier than 2018-05-25 |
| 538 |  | Publishing & Deployment Policy | 4d | 2018-05-29 | 2018-06-01 |  |  | 151d | finish no earlier than 2018-06-01 |
| 539 |  | Admin Policy | 4d? | 2018-05-29 | 2018-06-01 |  |  | 151d | finish no earlier than 2018-06-01 |
| 540 |  | Naming Convention | 4d? | 2018-05-29 | 2018-06-01 |  |  | 151d | finish no earlier than 2018-06-01 |
| 541 | 2 | **Deffered Tasks** | 218d? | 2018-03-01 A | 2018-12-31 |  | 2% | 0d |  |
| 542 | 2.1 | **Indoor maps - DEFERRED** | 86d | 2018-09-03 A | 2018-12-31 |  |  |  |  |
| 543 |  | Floor plans | 86d | 2018-09-03 A | 2018-12-31 |  | 1% |  |  |
| 544 |  | Google Maps | 86d | 2018-09-03 A | 2018-12-31 |  | 1% |  |  |
| 545 | 2.1.3 | **Testing** | 86d | 2018-09-03 | 2018-12-31 |  |  |  |  |
| 546 |  | Dev Testing | 86d | 2018-09-03 | 2018-12-31 |  |  |  |  |
| 547 |  | UI/UX Testing | 86d | 2018-09-03 | 2018-12-31 |  |  |  |  |
| 548 |  | BO Testing | 86d | 2018-09-03 | 2018-12-31 |  |  |  |  |
| 549 | 2.1.3.4 | **Functional Testing** | 86d | 2018-09-03 | 2018-12-31 |  |  |  |  |
| 550 |  | Mobile Web | 86d | 2018-09-03 | 2018-12-31 |  |  |  |  |
| 551 |  | iOS | 86d | 2018-09-03 | 2018-12-31 |  |  |  |  |
| 552 |  | Android | 86d | 2018-09-03 | 2018-12-31 |  |  |  |  |
| 553 |  | Usability Testing | 86d | 2018-09-03 | 2018-12-31 |  |  |  |  |
| 554 |  | Bug Fixing | 86d | 2018-09-03 | 2018-12-31 |  |  |  |  |
| 555 |  | Marketing sign-off | 86d | 2018-09-03 | 2018-12-31 |  |  |  |  |
| 556 | 2.2 | **TouchNet - DEFERRED** | 86d? | 2018-09-03 | 2018-12-31 |  |  |  |  |
| 557 |  | Schedule technical meetings | 86d? | 2018-09-03 | 2018-12-31 |  |  | 0d | start no earlier than 2018-09-03 |
| 558 | 2.3 | **Grade Center - DEFERRED** | 86d? | 2018-09-03 | 2018-12-31 |  |  |  |  |
| 559 |  | Stakeholder Meeting | 86d? | 2018-09-03 | 2018-12-31 |  |  | 0d | finish no earlier than 2018-12-31 |
| 560 |  | Blackboard Integration | 86d? | 2018-09-03 | 2018-12-31 |  |  | 0d | start no earlier than 2018-09-03 |

| ID | WBS | Task | Duration | Start | Finish | Predecessors | Complete | Total float | Constraint |
| --- | --- | --- | --- | --- | --- | --- | --- | --- | --- |
| 561 |  | PeopleSoft Integration | 86d? | 2018-09-03 | 2018-12-31 |  |  | 0d | start no earlier than 2018-09-03 |
| 562 |  | Casa Integration | 1d? | 2018-12-31 | 2018-12-31 |  |  | 0d | finish no earlier than 2018-12-31 |
| 563 | 2.3.5 | **Testing** | 86d? | 2018-09-03 | 2018-12-31 |  |  |  |  |
| 564 |  | Dev Testing | 86d? | 2018-09-03 | 2018-12-31 |  |  | 0d | start no earlier than 2018-09-03 |
| 565 |  | UI/UX Testing | 86d? | 2018-09-03 | 2018-12-31 |  |  | 0d | start no earlier than 2018-09-03 |
| 566 |  | BO Testing | 86d? | 2018-09-03 | 2018-12-31 |  |  | 0d | start no earlier than 2018-09-03 |
| 567 | 2.3.5.4 | **Functional Testing** | 86d? | 2018-09-03 | 2018-12-31 |  |  |  |  |
| 568 |  | Mobile Web | 86d? | 2018-09-03 | 2018-12-31 |  |  | 0d | start no earlier than 2018-09-03 |
| 569 |  | iOS | 86d? | 2018-09-03 | 2018-12-31 |  |  | 0d | start no earlier than 2018-09-03 |
| 570 |  | Android | 86d? | 2018-09-03 | 2018-12-31 |  |  | 0d | start no earlier than 2018-09-03 |
| 571 |  | Usability Testing | 86d? | 2018-09-03 | 2018-12-31 |  |  | 0d | start no earlier than 2018-09-03 |
| 572 |  | Bug Fixing | 86d? | 2018-09-03 | 2018-12-31 |  |  | 0d | start no earlier than 2018-09-03 |
| 573 |  | Marketing sign-off | 86d? | 2018-09-03 | 2018-12-31 |  |  | 0d | start no earlier than 2018-09-03 |
| 574 | 2.4 | **Institutional** | 54d | 2018-06-19 | 2018-08-31 |  |  | 86d |  |
| 575 | 2.4.1 | **MAPP creation** | 54d | 2018-06-19 | 2018-08-31 |  |  | 86d |  |
| 576 |  | Draft | 14d | 2018-06-19 | 2018-07-06 |  |  | 126d | start no earlier than 2018-06-18 |
| 577 |  | Final | 40d | 2018-07-09 | 2018-08-31 |  |  | 86d | start no earlier than 2018-07-09 |
| 578 |  | Privacy Policy | 6d | 2018-06-19 | 2018-06-26 |  |  | 134d | start no earlier than 2018-06-18 |
| 579 | 2.5 | **Grey Heller Future Phase** | 1d? | 2018-09-03 | 2018-09-03 |  |  | 0d |  |
| 580 | 2.5.1 | **Admissions (Deferred)** | 1d? | 2018-09-03 | 2018-09-03 |  |  |  |  |
| 581 |  | Admissions: Application Fee Payment | 1d | 2018-09-03 | 2018-09-03 |  |  | 85d |  |
| 582 |  | Admissions: Apply for UH Scholarships | 1d? | 2018-09-03 | 2018-09-03 |  |  | 85d |  |
| 583 |  | Admissions: Application Status | 1d? | 2018-09-03 | 2018-09-03 |  |  | 85d |  |
| 584 |  | Admissions: New Student Conference | 1d? | 2018-09-03 | 2018-09-03 |  |  | 85d |  |
| 585 | 2.5.1.5 | **Testing** | 1d? | 2018-09-03 | 2018-09-03 |  |  | 85d |  |
| 586 |  | Set up test accounts | 1d? | 2018-09-03 | 2018-09-03 |  |  | 85d |  |
| 587 |  | Identify testers | 1d? | 2018-09-03 | 2018-09-03 |  |  | 85d |  |
| 588 |  | Perform Dev Test | 1d? | 2018-09-03 | 2018-09-03 |  |  | 85d |  |
| 589 |  | Perform UI/UX Test | 1d? | 2018-09-03 | 2018-09-03 |  |  | 85d |  |
| 590 |  | Perform Functional Test | 1d? | 2018-09-03 | 2018-09-03 |  |  | 85d |  |
| 591 |  | Perform Usability Test | 1d | 2018-09-03 | 2018-09-03 |  |  | 85d | finish no earlier than 2018-06-01 |
| 592 |  | Migrations | 1d? | 2018-09-03 | 2018-09-03 |  |  | 85d |  |
| 593 |  | Move to Production | 1d? | 2018-09-03 | 2018-09-03 |  |  | 85d |  |
| 594 | 2.5.2 | **Faculty (Deferred)** | 1d? | 2018-09-03 | 2018-09-03 |  |  | 85d |  |
| 595 |  | Faculty: Class Roster | 1d? | 2018-09-03 | 2018-09-03 |  |  | 85d | start no earlier than 2018-09-03 |
| 596 |  | Faculty: Grade Roster | 1d? | 2018-09-03 | 2018-09-03 |  |  | 85d | start no earlier than 2018-09-03 |
| 597 |  | Faculty: Faculty Center | 1d? | 2018-09-03 | 2018-09-03 |  |  | 85d | start no earlier than 2018-09-03 |
| 598 |  | Faculty: Faculty Worklist | 1d? | 2018-09-03 | 2018-09-03 |  |  | 85d | start no earlier than 2018-09-03 |
| 599 | 2.5.2.5 | **Testing** | 1d? | 2018-09-03 | 2018-09-03 |  |  | 85d |  |
| 600 |  | Set up test accounts | 1d? | 2018-09-03 | 2018-09-03 |  |  | 85d | start no earlier than 2018-09-03 |
| 601 |  | Identify testers | 1d? | 2018-09-03 | 2018-09-03 |  |  | 85d | start no earlier than 2018-09-03 |
| 602 |  | Perform Dev Test | 1d? | 2018-09-03 | 2018-09-03 |  |  | 85d | start no earlier than 2018-09-03 |
| 603 |  | Perform UI/UX Test | 1d? | 2018-09-03 | 2018-09-03 |  |  | 85d | start no earlier than 2018-09-03 |
| 604 |  | Perform Functional Test | 1d? | 2018-09-03 | 2018-09-03 |  |  | 85d | start no earlier than 2018-09-03 |
| 605 |  | Perform Usability Test | 1d? | 2018-09-03 | 2018-09-03 |  |  | 85d | start no earlier than 2018-09-03 |
| 606 |  | Migrations | 1d? | 2018-09-03 | 2018-09-03 |  |  | 85d | start no earlier than 2018-09-03 |
| 607 |  | Move to Production | 1d? | 2018-09-03 | 2018-09-03 |  |  | 85d | start no earlier than 2018-09-03 |
| 608 | 2.6 | **Phase 5 - Advising** | 94d? | 2018-03-01 A | 2018-07-10 |  | 49% | 124d |  |
| 609 |  | Admissions: Application Fee Payment | 1d? | 2018-03-01 | 2018-03-01 |  |  |  | start no earlier than 2018-06-18 |
| 610 |  | Faculty: Faculty Center | 1d? | 2018-03-01 | 2018-03-01 |  |  |  | start no earlier than 2018-06-18 |
| 611 |  | Admissions: Apply for UH Scholarships | 1d? | 2018-03-01 | 2018-03-01 |  |  |  | start no earlier than 2018-06-18 |
| 612 |  | Faculty: Grade Roster | 1d? | 2018-03-01 | 2018-03-01 |  |  |  | start no earlier than 2018-06-18 |
| 613 |  | Faculty: Class Froster | 1d? | 2018-03-01 | 2018-03-01 |  |  |  | start no earlier than 2018-06-18 |
| 614 |  | Faculty: Faculty Worklist | 1d? | 2018-03-01 | 2018-03-01 |  |  |  | start no earlier than 2018-06-18 |
| 615 |  | Housing: Housing Information | 1d? | 2018-03-01 | 2018-03-01 |  |  |  | start no earlier than 2018-06-18 |
| 616 |  | Admissions: New Student Conference | 1d? | 2018-03-01 | 2018-03-01 |  |  |  | start no earlier than 2018-06-18 |
| 617 |  | Admissions: Application Status | 1d? | 2018-03-01 | 2018-03-01 |  |  |  | start no earlier than 2018-06-18 |
| 618 |  | Financial Aid: FSA ID Website link | 1d? | 2018-03-01 | 2018-03-01 |  |  |  | start no earlier than 2018-06-18 |
| 619 |  | Personal Info: Housing | 1d? | 2018-03-01 | 2018-03-01 |  |  |  | start no earlier than 2018-06-18 |
| 620 |  | Financial Aid: FAFSA on the web link | 1d? | 2018-03-01 | 2018-03-01 |  |  |  | start no earlier than 2018-06-18 |
| 621 |  | Personal Info: Demographic Information | 1d? | 2018-03-01 | 2018-03-01 |  |  |  | start no earlier than 2018-06-18 |
| 622 |  | Financial Aid: Student Loans link | 1d? | 2018-06-19 | 2018-06-19 |  |  | 139d | start no earlier than 2018-06-18 |
| 623 |  | JumpForward: JumpForward Website | 1d? | 2018-03-01 | 2018-03-01 |  |  |  | start no earlier than 2018-06-18 |
| 624 |  | Financial Aid: NSLDS Student Access link | 1d? | 2018-06-19 | 2018-06-19 |  |  | 139d | start no earlier than 2018-06-18 |
| 625 | 2.6.17 | **Testing** | 94d? | 2018-03-01 A | 2018-07-10 |  | 58% | 124d |  |
| 626 |  | Set up test accounts | 8d? | 2018-03-01 A | 2018-03-12 A |  | 100% |  | finish no earlier than 2018-03-12 |
| 627 |  | Identify testers | 44d? | 2018-03-01 A | 2018-05-01 A |  | 100% |  | finish no earlier than 2018-05-01 |
| 628 |  | Perform Dev Test | 5d? | 2018-05-21 | 2018-05-25 |  |  | 125d | finish no earlier than 2018-05-25 |
| 629 |  | Perform UI/UX Test | 15d? | 2018-05-28 | 2018-06-15 | 628 |  | 125d | finish no earlier than 2018-06-15 |
| 630 |  | Perform Functional Test | 11d? | 2018-06-19 | 2018-07-03 | 629 |  | 124d | start no earlier than 2018-06-18 |

| ID | WBS | Task | Duration | Start | Finish | Predecessors | Total float | Constraint |
| --- | --- | --- | --- | --- | --- | --- | --- | --- |
| 631 |  | Perform Usability Test | 5d? | 2018-07-04 | 2018-07-10 | 630 | 124d | finish no earlier than 2018-07-09 |
| 632 |  | Functional retest before moving to prod (links) | 1d | 2018-07-02 | 2018-07-02 |  |  |  |
| 633 | 2.6.18 | **Migrations** | 2d? | 2018-07-03 | 2018-07-05 |  | 0d |  |
| 634 |  | Move to TEST | 1d | 2018-07-03 | 2018-07-03 | 632 |  |  |
| 635 |  | Move to Production | 1d? | 2018-07-04 | 2018-07-04 | 634 | 128d | start no earlier than 2018-07-02 |
| 636 |  | MS: Phase 5 Completed | 0d | 2018-07-05 | 2018-07-05 | 635 |  |  |
| 637 |  | MS: Go-Live | 1d? | 2018-08-03 | 2018-08-03 |  |  |  |
| 638 |  | Integration Data Development / Testing Complete | 1d | 2018-07-16 | 2018-07-16 |  |  |  |
| 639 |  | Data Integration Development / Testing Complete | 1d? | 2018-07-16 | 2018-07-16 |  |  |  |

## Version 2 (data date 2018-06-18, saved 2019-10-02, file uh-mobile-plan-current-students-6-20-18-educause-template.mpp)

Last finish stays 2018-12-31. Complete tasks 112 → 100.

Changed:

| ID | Task | Start | Finish | Duration | Complete | Total float |
| --- | --- | --- | --- | --- | --- | --- |
| 1 | **UH Mobile Project** | 2017-02-08 A |  |  | 43% → 32% |  |
| 32 | **Grey Heller Implementation** | 2018-02-20 A → 2018-02-20 |  |  | 58% → 0% | 99.2d → none |
| 33 | **Current Students** | 2018-02-20 A → 2018-02-20 | 2018-08-14 → 2018-08-09 (-5d) | 125.8d? → 123d? | 58% → 0% | 99.2d → none |
| 34 | **Phase 0 - Grades, Schedule, Add, Drop, Swap** | 2018-02-20 A → 2018-02-20 |  |  | 63% → 0% | 117.3d → none |
| 35 | Install | 2018-02-20 A → 2018-02-20 | 2018-05-18 A → 2018-05-18 |  | 100% → 0% | none → 161d |
| 36 | Class Search | 2018-06-19 → 2018-06-18 (-1d) | 2018-06-25 → 2018-06-18 (-7d) | 5d → 0d |  | 135d → 140d |
| 37 | Academic Records: View My Grades | 2018-06-19 → 2018-06-18 (-1d) | 2018-06-25 → 2018-06-18 (-7d) | 5d → 0d |  | 135d → 140d |
| 38 | Academic Records: My Class Schedule |  | 2018-06-25 → 2018-06-19 (-6d) | 5d → 1d? |  | 135d → 139d |
| 39 | Academic Records: Enrollment: Add Classes |  | 2018-06-25 → 2018-06-19 (-6d) | 5d → 1d? |  | 135d → 139d |
| 40 | Academic Records: Enrollment: Drop Classes |  | 2018-06-25 → 2018-06-19 (-6d) | 5d → 1d? |  | 135d → 139d |
| 41 | Navigation |  | 2018-02-26 → 2018-02-20 (-6d) | 5d → 1d? |  |  |
| 42 | Tiling |  | 2018-02-26 → 2018-02-20 (-6d) | 5d → 1d? |  |  |
| 44 | Student Center: Shopping Cart |  | 2018-06-25 → 2018-06-19 (-6d) | 5d → 1d? |  | 135d → 139d |
| 45 | Student Center: Enroll - Swap a Class |  | 2018-06-25 → 2018-06-19 (-6d) | 5d → 1d? |  | 135d → 139d |
| 46 | Firewall Configuration for Modo Integration | 2018-02-20 A → 2018-02-20 | 2018-02-20 A → 2018-02-20 |  | 100% → 0% | none → 224d |
| 47 | **Testing** | 2018-03-01 A → 2018-03-01 |  |  | 71% → 0% | 115.3d → none |
| 48 | Set up test accounts | 2018-03-01 A → 2018-03-01 | 2018-03-12 A → 2018-03-12 |  | 100% → 0% | none → 210d |
| 49 | Identify testers | 2018-03-01 A → 2018-03-01 | 2018-05-01 A → 2018-05-01 |  | 100% → 0% | none → 174d |
| 50 | Perform Dev Test | 2018-06-08 A → 2018-06-08 |  |  | 55% → 0% | 115.3d → 131.3d |
| 51 | Perform UI/UX Test | 2018-06-21 → 2018-06-22 (+1d) | 2018-06-28 → 2018-06-22 (-6d) | 5d? → 1d? |  | 115.3d → 131d |
| 52 | Perform BO Functional Test | 2018-06-28 → 2018-07-06 (+8d) | 2018-07-12 → 2018-07-06 (-6d) | 10d? → 1d? |  | 115.3d → 122d |
| 53 | Perform Usability Test | 2018-07-12 → 2018-07-09 (-3d) | 2018-07-19 → 2018-07-09 (-10d) | 5d? → 1d? |  | 115.3d → 122d |
| 54 | **Migrations** |  | 2018-07-12 → 2018-07-10 (-2d) | 2d? → 1d? |  | 0d → none |
| 57 | MS: Phase 0 Completed |  |  | 0d → 1d? |  |  |
| 58 | **Phase 1 - Personal Information** | 2018-03-01 A → 2018-03-01 | 2018-07-17 → 2018-07-13 (-4d) | 98.05d? → 97d? | 62% → 0% | 119.95d → none |
| 59 | Personal Info: Emergency Contacts |  |  | 1d → 1d? |  |  |
| 72 | **Testing** | 2018-03-01 A → 2018-03-01 | 2018-07-17 → 2018-07-13 (-4d) | 98.05d? → 97d? | 74% → 0% | 117.95d → 121d |
| 73 | Set up test accounts | 2018-03-01 A → 2018-03-01 | 2018-03-12 A → 2018-03-12 |  | 100% → 0% | none → 210d |
| 74 | Identify testers | 2018-03-01 A → 2018-03-01 | 2018-05-01 A → 2018-05-01 |  | 100% → 0% | none → 174d |
| 75 | Perform Dev Test | 2018-06-08 A → 2018-06-06 (-2d) | 2018-06-20 → 2018-06-18 (-2d) |  | 85% → 0% | 117.95d → 119d |
| 76 | Perform UI/UX Test | 2018-06-20 → 2018-06-19 (-1d) | 2018-06-26 → 2018-06-22 (-4d) |  |  | 117.95d → 119d |
| 77 | Perform Functional Test | 2018-06-26 → 2018-06-25 (-1d) | 2018-07-10 → 2018-07-06 (-4d) |  |  | 117.95d → 119d |
| 78 | Perform Usability Test | 2018-07-10 → 2018-07-09 (-1d) | 2018-07-17 → 2018-07-13 (-4d) |  |  | 117.95d → 119d |
| 83 | **Phase 2 - Financial Aid** | 2018-03-01 A → 2018-03-01 | 2018-08-14 → 2018-08-09 (-5d) | 118.8d? → 116d? | 54% → 0% | 99.2d → 78d |
| 89 | **Testing** | 2018-03-01 A → 2018-03-01 | 2018-08-14 → 2018-08-09 (-5d) | 118.8d? → 116d? | 58% → 0% | 99.2d → 102d |
| 90 | Set up test accounts | 2018-03-01 A → 2018-03-01 | 2018-03-12 A → 2018-03-12 |  | 100% → 0% | none → 210d |
| 91 | Identify testers | 2018-03-01 A → 2018-03-01 | 2018-05-01 A → 2018-05-01 |  | 100% → 0% | none → 174d |
| 92 | Perform Dev Test | 2018-06-08 A → 2018-06-05 (-3d) | 2018-06-21 → 2018-06-18 (-3d) |  | 60% → 0% | 99.2d → 102d |
| 93 | Perform UI/UX Test | 2018-06-21 → 2018-06-19 (-2d) | 2018-06-27 → 2018-06-22 (-5d) |  |  | 99.2d → 102d |
| 94 | Perform Functional Test | 2018-06-27 → 2018-06-25 (-2d) | 2018-07-11 → 2018-07-06 (-5d) |  |  | 99.2d → 102d |
| 95 | Perform Usability Test | 2018-07-11 → 2018-07-09 (-2d) | 2018-08-14 → 2018-08-09 (-5d) |  |  | 99.2d → 102d |
| 100 | **Phase 3 - Academic Records, Enrollment** | 2018-03-01 A → 2018-03-01 | 2018-07-18 → 2018-07-17 (-1d) | 99.57d? → 99d? | 54% → 0% | 118.43d → 0d |
| 116 | **Testing** | 2018-03-01 A → 2018-03-01 | 2018-07-18 → 2018-07-17 (-1d) | 99.57d? → 99d? | 65% → 0% | 118.43d → 119d |
| 117 | Set up test accounts | 2018-03-01 A → 2018-03-01 | 2018-03-12 A → 2018-03-12 |  | 100% → 0% | none → 210d |
| 118 | Identify testers | 2018-03-01 A → 2018-03-01 | 2018-05-01 A → 2018-05-01 |  | 100% → 0% | none → 174d |
| 119 | Perform Dev Test | 2018-06-08 A → 2018-06-08 | 2018-06-19 → 2018-06-08 (-11d) |  | 43% → 0% | 118.43d → 125d |
| 120 | Perform UI/UX Test |  | 2018-07-03 → 2018-07-02 (-1d) |  |  | 118.43d → 119d |
| 121 | Perform Functional Test |  | 2018-07-18 → 2018-07-17 (-1d) |  |  | 118.43d → 119d |
| 127 | **Phase 4 - Student Financials** | 2018-03-01 A → 2018-03-01 |  | 96.85d? → 96d? | 56% → 0% | 121.15d → 0d |
| 150 | **Testing** | 2018-03-01 A → 2018-03-01 | 2018-07-13 → 2018-07-10 (-3d) | 96.85d? → 94d? | 75% → 0% | 119.15d → 124d |
| 151 | Set up test accounts | 2018-03-01 A → 2018-03-01 | 2018-03-12 A → 2018-03-12 |  | 100% → 0% | none → 210d |
| 152 | Identify testers | 2018-03-01 A → 2018-03-01 | 2018-05-01 A → 2018-05-01 |  | 100% → 0% | none → 174d |
| 153 | Perform Dev Test | 2018-06-08 A → 2018-06-08 | 2018-06-22 → 2018-06-18 (-4d) |  | 45% → 0% | 119.15d → 123d |
| 154 | Perform UI/UX Test | 2018-06-22 → 2018-06-19 (-3d) | 2018-06-28 → 2018-06-22 (-6d) |  |  | 119.15d → 123d |
| 155 | Perform Functional Test | 2018-06-28 → 2018-06-25 (-3d) | 2018-07-12 → 2018-07-06 (-6d) |  |  | 119.15d → 123d |
| 156 | Perform Usability Test | 2018-07-12 → 2018-07-10 (-2d) | 2018-07-13 → 2018-07-10 (-3d) |  |  | 119.15d → 122d |
